# 67 Ulrich St

How a schedule from MS Project changed from version to version. A marks actual dates.

## Version 1 (saved 2016-05-24, file Views_1.mpp)

| ID | WBS | Task | Duration | Start | Finish | Predecessors | Total float |
| --- | --- | --- | --- | --- | --- | --- | --- |
| 1 | 1 | **Plans and Site** | 34d | 2019-01-15 | 2019-03-01 |  | 0d |
| 2 |  | Create Site Plans | 2d | 2019-01-15 | 2019-01-16 |  | 0d |
| 3 |  | Arrange Council Permits | 2d | 2019-01-17 | 2019-01-18 | 2 | 0d |
| 4 |  | Prepare Site | 10d | 2019-02-08 | 2019-02-21 | 3FS+14d | 0d |
| 5 |  | Organise Materials | 1d | 2019-02-08 | 2019-02-08 | 4SS | 58d |
| 6 |  | Lay Foundations | 4d | 2019-02-22 | 2019-02-27 | 4 | 0d |
| 7 |  | Plumbing for Sewerage | 1d | 2019-02-28 | 2019-02-28 | 6 | 0d |
| 8 |  | Pour Slab | 1d | 2019-03-01 | 2019-03-01 | 7 | 0d |
| 9 |  | Site Complete | 0d | 2019-03-01 | 2019-03-01 | 8 | 0d |
| 10 | 2 | **To Lock Up** | 22d | 2019-03-04 | 2019-04-02 | 9 | 0d |
| 11 |  | Erect Framing | 3d | 2019-03-04 | 2019-03-06 |  | 0d |
| 12 |  | Lay Roofing | 12d | 2019-03-07 | 2019-03-22 | 11 | 0d |
| 13 |  | Brick Walls | 5d | 2019-03-25 | 2019-03-29 | 12 | 0d |
| 14 |  | Fit Windows & Doors | 2d | 2019-04-01 | 2019-04-02 | 13 | 0d |
| 15 |  | Lockup | 0d | 2019-04-02 | 2019-04-02 | 14 | 0d |
| 16 | 3 | **Fit Out** | 21d | 2019-04-03 | 2019-05-01 | 15 | 0d |
| 17 |  | Electrical Cables | 1d | 2019-04-03 | 2019-04-03 |  | 0d |
| 18 |  | Internal Plumbing | 2d | 2019-04-03 | 2019-04-04 | 17SS | 0d |
| 19 |  | Plaster Walls | 5d | 2019-04-05 | 2019-04-11 | 18 | 0d |
| 20 |  | Internal Doors and Trim | 4d | 2019-04-12 | 2019-04-17 | 19 | 0d |
| 21 |  | Install Kitchen | 3d | 2019-04-18 | 2019-04-22 | 20 | 0d |
| 22 |  | Install Bathroom | 2d | 2019-04-18 | 2019-04-19 | 21SS | 0d |
| 23 |  | Final Electrical Fittings | 2d | 2019-04-22 | 2019-04-23 | 22 | 0d |
| 24 |  | Final Plumbing Fittings | 2d | 2019-04-22 | 2019-04-23 | 23SS | 0d |
| 25 |  | Paint | 5d | 2019-04-24 | 2019-04-30 | 24 | 0d |
| 26 |  | Council Approval | 1d | 2019-05-01 | 2019-05-01 | 25 | 0d |
| 27 |  | Construction Completed | 0d | 2019-05-01 | 2019-05-01 | 26 | 0d |

## Version 2 (saved 2016-06-08, file Templates_1.mpp)

Last finish 2019-05-01 → 2019-09-19 (+141d).

Removed: 1 Plans and Site; 10 To Lock Up; 16 Fit Out

Changed:

| ID | Task | Start | Finish | Duration | Total float | Predecessors | Other |
| --- | --- | --- | --- | --- | --- | --- | --- |
| 1 | Create Site Plans | 2019-01-15 → 2019-07-01 (+167d) | 2019-01-16 → 2019-07-02 (+167d) |  |  |  |  |
| 2 | Arrange Council Permits | 2019-01-17 → 2019-07-03 (+167d) | 2019-01-18 → 2019-07-03 (+166d) | 2d → 1d |  |  |  |
| 3 | Prepare Site | 2019-02-08 → 2019-07-24 (+166d) | 2019-02-21 → 2019-07-26 (+155d) | 10d → 3d |  |  |  |
| 4 | Organise Materials | 2019-02-08 → 2019-07-24 (+166d) | 2019-02-08 → 2019-07-24 (+166d) |  | 58d → 41d |  |  |
| 5 | Lay Foundations | 2019-02-22 → 2019-07-29 (+157d) | 2019-02-27 → 2019-07-30 (+153d) | 4d → 2d |  |  |  |
| 6 | Plumbing for Sewerage | 2019-02-28 → 2019-07-31 (+153d) | 2019-02-28 → 2019-07-31 (+153d) |  |  |  |  |
| 7 | Pour Slab | 2019-03-01 → 2019-08-01 (+153d) | 2019-03-01 → 2019-08-01 (+153d) |  |  |  |  |
| 8 | Foundations Complete | 2019-03-01 → 2019-08-01 (+153d) | 2019-03-01 → 2019-08-01 (+153d) |  |  |  | was named Site Complete |
| 9 | Erect Framing | 2019-03-04 → 2019-08-02 (+151d) | 2019-03-06 → 2019-08-06 (+153d) |  |  | none → 8 |  |
| 10 | Lay Roofing | 2019-03-07 → 2019-08-07 (+153d) | 2019-03-22 → 2019-08-09 (+140d) | 12d → 3d |  |  |  |
| 11 | Brick Walls | 2019-03-25 → 2019-08-12 (+140d) | 2019-03-29 → 2019-08-16 (+140d) |  |  |  |  |
| 12 | Fit Windows & Doors | 2019-04-01 → 2019-08-19 (+140d) | 2019-04-02 → 2019-08-20 (+140d) |  |  |  |  |
| 13 | Lockup | 2019-04-02 → 2019-08-20 (+140d) | 2019-04-02 → 2019-08-20 (+140d) |  |  |  |  |
| 14 | Electrical Cables | 2019-04-03 → 2019-08-21 (+140d) | 2019-04-03 → 2019-08-21 (+140d) |  |  | none → 13 |  |
| 15 | Internal Plumbing | 2019-04-03 → 2019-08-21 (+140d) | 2019-04-04 → 2019-08-21 (+139d) | 2d → 1d |  |  |  |
| 16 | Plaster Walls | 2019-04-05 → 2019-08-22 (+139d) | 2019-04-11 → 2019-08-28 (+139d) |  |  |  |  |
| 17 | Internal Doors and Trim | 2019-04-12 → 2019-08-29 (+139d) | 2019-04-17 → 2019-09-03 (+139d) |  |  |  |  |
| 18 | Install Kitchen | 2019-04-18 → 2019-09-04 (+139d) | 2019-04-22 → 2019-09-05 (+136d) | 3d → 2d |  |  |  |
| 19 | Install Bathroom | 2019-04-18 → 2019-09-04 (+139d) | 2019-04-19 → 2019-09-09 (+143d) | 2d → 4d |  |  |  |
| 20 | Final Electrical Fittings | 2019-04-22 → 2019-09-10 (+141d) | 2019-04-23 → 2019-09-11 (+141d) |  |  |  |  |
| 21 | Final Plumbing Fittings | 2019-04-22 → 2019-09-10 (+141d) | 2019-04-23 → 2019-09-11 (+141d) |  |  |  |  |
| 22 | Paint | 2019-04-24 → 2019-09-12 (+141d) | 2019-04-30 → 2019-09-18 (+141d) |  |  |  |  |
| 23 | Council Approval | 2019-05-01 → 2019-09-19 (+141d) | 2019-05-01 → 2019-09-19 (+141d) |  |  |  |  |
| 24 | Construction Completed | 2019-05-01 → 2019-09-19 (+141d) | 2019-05-01 → 2019-09-19 (+141d) |  |  |  |  |

## Version 3 (saved 2016-06-17, file House_4.mpp)

Last finish 2019-09-19 → 2019-06-21 (-90d).

Added:

| ID | Task | Duration | Start | Finish | Predecessors |
| --- | --- | --- | --- | --- | --- |
| 1 | **Plans and Site** | 37d | 2019-03-04 | 2019-04-23 |  |
| 10 | **To Lock Up** | 22d | 2019-04-24 | 2019-05-23 | 9 |
| 16 | **Fit Out** | 21d | 2019-05-24 | 2019-06-21 | 15 |

Changed:

| ID | Task | Start | Finish | Duration | Total float | Predecessors |
| --- | --- | --- | --- | --- | --- | --- |
| 2 | Create Site Plans | 2019-07-01 → 2019-03-04 (-119d) | 2019-07-02 → 2019-03-15 (-109d) | 2d → 10d |  |  |
| 3 | Arrange Council Permits | 2019-07-03 → 2019-03-18 (-107d) | 2019-07-03 → 2019-03-19 (-106d) | 1d → 2d |  |  |
| 4 | Prepare Site | 2019-07-24 → 2019-04-09 (-106d) | 2019-07-26 → 2019-04-15 (-102d) | 3d → 5d |  |  |
| 5 | Organise Materials | 2019-07-24 → 2019-04-09 (-106d) | 2019-07-24 → 2019-04-09 (-106d) |  | 41d → 53d |  |
| 6 | Lay Foundations | 2019-07-29 → 2019-04-16 (-104d) | 2019-07-30 → 2019-04-19 (-102d) | 2d → 4d |  |  |
| 7 | Plumbing for Sewerage | 2019-07-31 → 2019-04-22 (-100d) | 2019-07-31 → 2019-04-22 (-100d) |  |  |  |
| 8 | Pour Slab | 2019-08-01 → 2019-04-23 (-100d) | 2019-08-01 → 2019-04-23 (-100d) |  |  |  |
| 9 | Foundations Complete | 2019-08-01 → 2019-04-23 (-100d) | 2019-08-01 → 2019-04-23 (-100d) |  |  |  |
| 11 | Erect Framing | 2019-08-02 → 2019-04-24 (-100d) | 2019-08-06 → 2019-04-26 (-102d) |  |  | 9 → none |
| 12 | Lay Roofing | 2019-08-07 → 2019-04-29 (-100d) | 2019-08-09 → 2019-05-14 (-87d) | 3d → 12d |  |  |
| 13 | Brick Walls | 2019-08-12 → 2019-05-15 (-89d) | 2019-08-16 → 2019-05-21 (-87d) |  |  |  |
| 14 | Fit Windows & Doors | 2019-08-19 → 2019-05-22 (-89d) | 2019-08-20 → 2019-05-23 (-89d) |  |  |  |
| 15 | Lockup | 2019-08-20 → 2019-05-23 (-89d) | 2019-08-20 → 2019-05-23 (-89d) |  |  |  |
| 17 | Electrical Cables | 2019-08-21 → 2019-05-24 (-89d) | 2019-08-21 → 2019-05-24 (-89d) |  |  | 15 → none |
| 18 | Internal Plumbing | 2019-08-21 → 2019-05-24 (-89d) | 2019-08-21 → 2019-05-27 (-86d) | 1d → 2d |  |  |
| 19 | Plaster Walls | 2019-08-22 → 2019-05-28 (-86d) | 2019-08-28 → 2019-06-03 (-86d) |  |  |  |
| 20 | Internal Doors and Trim | 2019-08-29 → 2019-06-04 (-86d) | 2019-09-03 → 2019-06-07 (-88d) |  |  |  |
| 21 | Install Kitchen | 2019-09-04 → 2019-06-10 (-86d) | 2019-09-05 → 2019-06-12 (-85d) | 2d → 3d |  |  |
| 22 | Install Bathroom | 2019-09-04 → 2019-06-10 (-86d) | 2019-09-09 → 2019-06-11 (-90d) | 4d → 2d |  |  |
| 23 | Final Electrical Fittings | 2019-09-10 → 2019-06-12 (-90d) | 2019-09-11 → 2019-06-13 (-90d) |  |  |  |
| 24 | Final Plumbing Fittings | 2019-09-10 → 2019-06-12 (-90d) | 2019-09-11 → 2019-06-13 (-90d) |  |  |  |
| 25 | Paint | 2019-09-12 → 2019-06-14 (-90d) | 2019-09-18 → 2019-06-20 (-90d) |  |  |  |
| 26 | Council Approval | 2019-09-19 → 2019-06-21 (-90d) | 2019-09-19 → 2019-06-21 (-90d) |  |  |  |
| 27 | Construction Completed | 2019-09-19 → 2019-06-21 (-90d) | 2019-09-19 → 2019-06-21 (-90d) |  |  |  |

## Version 4 (saved 2016-06-17, file House_2.mpp)

Last finish stays 2019-06-21.

Changed:

| ID | Task | Start | Finish | Duration | Total float | Other |
| --- | --- | --- | --- | --- | --- | --- |
| 1 | **Plans and Site** | 2019-03-04 → 2019-03-12 (+8d) | 2019-04-23 → 2019-04-17 (-6d) | 37d → 27d |  |  |
| 2 | Create Site Plans | 2019-03-04 → 2019-03-12 (+8d) | 2019-03-15 → 2019-03-13 (-2d) | 10d → 2d |  |  |
| 3 | Arrange Council Permits | 2019-03-18 → 2019-03-14 (-4d) | 2019-03-19 → 2019-03-14 (-5d) | 2d → 1d |  |  |
| 4 | Prepare Site | 2019-04-09 → 2019-04-04 (-5d) | 2019-04-15 → 2019-04-08 (-7d) | 5d → 3d |  |  |
| 5 | Organise Materials | 2019-04-09 → 2019-04-04 (-5d) | 2019-04-09 → 2019-04-04 (-5d) |  | 53d → 56d |  |
| 6 | Lay Foundations | 2019-04-16 → 2019-04-09 (-7d) | 2019-04-19 → 2019-04-12 (-7d) |  |  |  |
| 7 | Plumbing for Sewerage | 2019-04-22 → 2019-04-15 (-7d) | 2019-04-22 → 2019-04-16 (-6d) | 1d → 2d |  |  |
| 8 | Pour Slab | 2019-04-23 → 2019-04-17 (-6d) | 2019-04-23 → 2019-04-17 (-6d) |  |  |  |
| 9 | Foundations Complete | 2019-04-23 → 2019-04-17 (-6d) | 2019-04-23 → 2019-04-17 (-6d) |  |  |  |
| 10 | **To Lock up** | 2019-04-24 → 2019-04-18 (-6d) | 2019-05-23 → 2019-05-24 (+1d) | 22d → 27d |  | was named To Lock Up |
| 11 | Erect Framing | 2019-04-24 → 2019-04-18 (-6d) | 2019-04-26 → 2019-04-22 (-4d) |  |  |  |
| 12 | Lay Roofing | 2019-04-29 → 2019-04-23 (-6d) | 2019-05-14 → 2019-05-01 (-13d) | 12d → 7d |  |  |
| 13 | Brick Walls | 2019-05-15 → 2019-05-02 (-13d) | 2019-05-21 → 2019-05-14 (-7d) | 5d → 9d |  |  |
| 14 | Fit Windows & Doors | 2019-05-22 → 2019-05-15 (-7d) | 2019-05-23 → 2019-05-24 (+1d) | 2d → 8d |  |  |
| 15 | Lockup | 2019-05-23 → 2019-05-24 (+1d) | 2019-05-23 → 2019-05-24 (+1d) |  |  |  |
| 16 | **Fit Out** | 2019-05-24 → 2019-05-27 (+3d) |  | 21d → 20d |  |  |
| 17 | Electrical Cables | 2019-05-24 → 2019-05-27 (+3d) | 2019-05-24 → 2019-05-27 (+3d) |  |  |  |
| 18 | Internal Plumbing | 2019-05-24 → 2019-05-27 (+3d) |  | 2d → 1d |  |  |
| 21 | Install Kitchen |  | 2019-06-12 → 2019-06-11 (-1d) | 3d → 2d |  |  |

## Version 5 (saved 2016-06-17, file House_3.mpp)

Last finish 2019-06-21 → 2019-05-28 (-24d).

Changed:

| ID | Task | Start | Finish | Duration | Total float | Other |
| --- | --- | --- | --- | --- | --- | --- |
| 1 | **Plans and Site** | 2019-03-12 → 2019-02-19 (-21d) | 2019-04-17 → 2019-03-29 (-19d) | 27d → 29d | 0d → 18d |  |
| 2 | Create Site Plans | 2019-03-12 → 2019-02-19 (-21d) | 2019-03-13 → 2019-02-21 (-20d) | 2d → 3d | 0d → 18d |  |
| 3 | Arrange Council Permits | 2019-03-14 → 2019-02-22 (-20d) | 2019-03-14 → 2019-02-22 (-20d) |  | 0d → 18d |  |
| 4 | Prepare Site | 2019-04-04 → 2019-03-15 (-20d) | 2019-04-08 → 2019-03-21 (-18d) | 3d → 5d | 0d → 18d |  |
| 5 | Organise Materials | 2019-04-04 → 2019-03-15 (-20d) | 2019-04-04 → 2019-03-15 (-20d) |  | 56d → 70d |  |
| 6 | Lay Foundations | 2019-04-09 → 2019-03-22 (-18d) | 2019-04-12 → 2019-03-26 (-17d) | 4d → 3d | 0d → 18d |  |
| 7 | Plumbing for Sewerage | 2019-04-15 → 2019-03-27 (-19d) | 2019-04-16 → 2019-03-27 (-20d) | 2d → 1d | 0d → 18d |  |
| 8 | Pour Slab | 2019-04-17 → 2019-03-28 (-20d) | 2019-04-17 → 2019-03-29 (-19d) | 1d → 2d | 0d → 18d |  |
| 9 | Foundations Complete | 2019-04-17 → 2019-03-29 (-19d) | 2019-04-17 → 2019-03-29 (-19d) |  | 0d → 18d |  |
| 10 | **To Lock Up** | 2019-04-18 → 2019-04-01 (-17d) | 2019-05-24 → 2019-04-24 (-30d) | 27d → 18d | 0d → 18d | was named To Lock up |
| 11 | Erect Framing | 2019-04-18 → 2019-04-01 (-17d) | 2019-04-22 → 2019-04-03 (-19d) |  | 0d → 18d |  |
| 12 | Lay Roofing | 2019-04-23 → 2019-04-04 (-19d) | 2019-05-01 → 2019-04-11 (-20d) | 7d → 6d | 0d → 18d |  |
| 13 | Brick Walls | 2019-05-02 → 2019-04-12 (-20d) | 2019-05-14 → 2019-04-18 (-26d) | 9d → 5d | 0d → 18d |  |
| 14 | Fit Windows & Doors | 2019-05-15 → 2019-04-19 (-26d) | 2019-05-24 → 2019-04-24 (-30d) | 8d → 4d | 0d → 18d |  |
| 15 | Lockup | 2019-05-24 → 2019-04-24 (-30d) | 2019-05-24 → 2019-04-24 (-30d) |  | 0d → 18d |  |
| 16 | **Fit Out** | 2019-05-27 → 2019-04-25 (-32d) | 2019-06-21 → 2019-05-28 (-24d) | 20d → 24d | 0d → 18d |  |
| 17 | Electrical Cables | 2019-05-27 → 2019-04-25 (-32d) | 2019-05-27 → 2019-04-25 (-32d) |  | 0d → 18d |  |
| 18 | Internal Plumbing | 2019-05-27 → 2019-04-25 (-32d) | 2019-05-27 → 2019-04-26 (-31d) | 1d → 2d | 0d → 18d |  |
| 19 | Plaster Walls | 2019-05-28 → 2019-04-29 (-29d) | 2019-06-03 → 2019-05-08 (-26d) | 5d → 8d | 0d → 18d |  |
| 20 | Internal Doors and Trim | 2019-06-04 → 2019-05-09 (-26d) | 2019-06-07 → 2019-05-14 (-24d) |  | 0d → 18d |  |
| 21 | Install Kitchen | 2019-06-10 → 2019-05-15 (-26d) | 2019-06-11 → 2019-05-17 (-25d) | 2d → 3d | 0d → 18d |  |
| 22 | Install Bathroom | 2019-06-10 → 2019-05-15 (-26d) | 2019-06-11 → 2019-05-16 (-26d) |  | 0d → 18d |  |
| 23 | Final Electrical Fittings | 2019-06-12 → 2019-05-17 (-26d) | 2019-06-13 → 2019-05-20 (-24d) |  | 0d → 18d |  |
| 24 | Final Plumbing Fittings | 2019-06-12 → 2019-05-17 (-26d) | 2019-06-13 → 2019-05-20 (-24d) |  | 0d → 18d |  |
| 25 | Paint | 2019-06-14 → 2019-05-21 (-24d) | 2019-06-20 → 2019-05-27 (-24d) |  | 0d → 18d |  |
| 26 | Council Approval | 2019-06-21 → 2019-05-28 (-24d) | 2019-06-21 → 2019-05-28 (-24d) |  | 0d → 18d |  |
| 27 | Construction Completed | 2019-06-21 → 2019-05-28 (-24d) | 2019-06-21 → 2019-05-28 (-24d) |  | 0d → 18d |  |

## Version 6 (saved 2016-06-17, file House_5.mpp)

Last finish 2019-05-28 → 2019-06-07 (+10d).

Changed:

| ID | Task | Start | Finish | Duration | Total float |
| --- | --- | --- | --- | --- | --- |
| 1 | **Plans and Site** | 2019-02-19 → 2019-02-05 (-14d) | 2019-03-29 → 2019-03-28 (-1d) | 29d → 38d | 18d → 10d |
| 2 | Create Site Plans | 2019-02-19 → 2019-02-05 (-14d) | 2019-02-21 → 2019-02-06 (-15d) | 3d → 2d | 18d → 10d |
| 3 | Arrange Council Permits | 2019-02-22 → 2019-02-07 (-15d) | 2019-02-22 → 2019-02-07 (-15d) |  | 18d → 10d |
| 4 | Prepare Site | 2019-03-15 → 2019-02-28 (-15d) | 2019-03-21 → 2019-03-06 (-15d) |  | 18d → 10d |
| 5 | Organise Materials | 2019-03-15 → 2019-02-28 (-15d) | 2019-03-15 → 2019-02-28 (-15d) |  | 70d → 81d |
| 6 | Lay Foundations | 2019-03-22 → 2019-03-07 (-15d) | 2019-03-26 → 2019-03-22 (-4d) | 3d → 12d | 18d → 10d |
| 7 | Plumbing for Sewerage | 2019-03-27 → 2019-03-25 (-2d) | 2019-03-27 → 2019-03-26 (-1d) | 1d → 2d | 18d → 10d |
| 8 | Pour Slab | 2019-03-28 → 2019-03-27 (-1d) | 2019-03-29 → 2019-03-28 (-1d) |  | 18d → 10d |
| 9 | Foundations Complete | 2019-03-29 → 2019-03-28 (-1d) | 2019-03-29 → 2019-03-28 (-1d) |  | 18d → 10d |
| 10 | **To Lock Up** | 2019-04-01 → 2019-03-29 (-3d) | 2019-04-24 → 2019-04-26 (+2d) | 18d → 21d | 18d → 10d |
| 11 | Erect Framing | 2019-04-01 → 2019-03-29 (-3d) | 2019-04-03 → 2019-04-02 (-1d) |  | 18d → 10d |
| 12 | Lay Roofing | 2019-04-04 → 2019-04-03 (-1d) | 2019-04-11 → 2019-04-08 (-3d) | 6d → 4d | 18d → 10d |
| 13 | Brick Walls | 2019-04-12 → 2019-04-09 (-3d) | 2019-04-18 → 2019-04-24 (+6d) | 5d → 12d | 18d → 10d |
| 14 | Fit Windows & Doors | 2019-04-19 → 2019-04-25 (+6d) | 2019-04-24 → 2019-04-26 (+2d) | 4d → 2d | 18d → 10d |
| 15 | Lockup | 2019-04-24 → 2019-04-26 (+2d) | 2019-04-24 → 2019-04-26 (+2d) |  | 18d → 10d |
| 16 | **Fit Out** | 2019-04-25 → 2019-04-29 (+4d) | 2019-05-28 → 2019-06-07 (+10d) | 24d → 30d | 18d → 10d |
| 17 | Electrical Cables | 2019-04-25 → 2019-04-29 (+4d) | 2019-04-25 → 2019-04-30 (+5d) | 1d → 2d | 18d → 10d |
| 18 | Internal Plumbing | 2019-04-25 → 2019-04-29 (+4d) | 2019-04-26 → 2019-04-30 (+4d) |  | 18d → 10d |
| 19 | Plaster Walls | 2019-04-29 → 2019-05-01 (+2d) | 2019-05-08 → 2019-05-16 (+8d) | 8d → 12d | 18d → 10d |
| 20 | Internal Doors and Trim | 2019-05-09 → 2019-05-17 (+8d) | 2019-05-14 → 2019-05-24 (+10d) | 4d → 6d | 18d → 10d |
| 21 | Install Kitchen | 2019-05-15 → 2019-05-27 (+12d) | 2019-05-17 → 2019-05-28 (+11d) | 3d → 2d | 18d → 10d |
| 22 | Install Bathroom | 2019-05-15 → 2019-05-27 (+12d) | 2019-05-16 → 2019-05-28 (+12d) |  | 18d → 10d |
| 23 | Final Electrical Fittings | 2019-05-17 → 2019-05-29 (+12d) | 2019-05-20 → 2019-05-31 (+11d) | 2d → 3d | 18d → 10d |
| 24 | Final Plumbing Fittings | 2019-05-17 → 2019-05-29 (+12d) | 2019-05-20 → 2019-05-30 (+10d) |  | 18d → 10d |
| 25 | Paint | 2019-05-21 → 2019-05-31 (+10d) | 2019-05-27 → 2019-06-06 (+10d) |  | 18d → 10d |
| 26 | Council Approval | 2019-05-28 → 2019-06-07 (+10d) | 2019-05-28 → 2019-06-07 (+10d) |  | 18d → 10d |
| 27 | Construction Completed | 2019-05-28 → 2019-06-07 (+10d) | 2019-05-28 → 2019-06-07 (+10d) |  | 18d → 10d |

## Version 7 (saved 2016-06-20, file House_1.mpp)

Last finish 2019-06-07 → 2019-07-17 (+40d).

Changed:

| ID | Task | Start | Finish | Duration | Total float | Predecessors |
| --- | --- | --- | --- | --- | --- | --- |
| 1 | **Plans and Site** | 2019-02-05 → 2019-03-19 (+42d) | 2019-03-28 → 2019-05-31 (+64d) | 38d → 54d | 10d → 0d |  |
| 2 | Create Site Plans | 2019-02-05 → 2019-03-19 (+42d) | 2019-02-06 → 2019-04-01 (+54d) | 2d → 10d | 10d → 0d |  |
| 3 | Arrange Council Permits | 2019-02-07 → 2019-04-02 (+54d) | 2019-02-07 → 2019-04-02 (+54d) |  | 10d → 0d |  |
| 4 | Prepare Site | 2019-02-28 → 2019-04-23 (+54d) | 2019-03-06 → 2019-05-08 (+63d) | 5d → 12d | 10d → 0d |  |
| 5 | Organise Materials | 2019-02-28 → 2019-04-23 (+54d) | 2019-02-28 → 2019-04-23 (+54d) |  | 81d → 61d |  |
| 6 | Lay Foundations | 2019-03-07 → 2019-05-09 (+63d) | 2019-03-22 → 2019-05-29 (+68d) | 12d → 15d | 10d → 0d |  |
| 7 | Plumbing for Sewerage | 2019-03-25 → 2019-05-30 (+66d) | 2019-03-26 → 2019-05-30 (+65d) | 2d → 1d | 10d → 0d |  |
| 8 | Pour Slab | 2019-03-27 → 2019-05-31 (+65d) | 2019-03-28 → 2019-05-31 (+64d) | 2d → 1d | 10d → 0d |  |
| 9 | Foundations Complete | 2019-03-28 → 2019-05-31 (+64d) | 2019-03-28 → 2019-05-31 (+64d) |  | 10d → 0d |  |
| 10 | **To Lock Up** | 2019-03-29 → 2019-06-03 (+66d) | 2019-04-26 → 2019-06-19 (+54d) | 21d → 13d | 10d → 0d | 9 → none |
| 11 | Erect Framing | 2019-03-29 → 2019-06-03 (+66d) | 2019-04-02 → 2019-06-05 (+64d) |  | 10d → 0d | none → 9 |
| 12 | Lay Roofing | 2019-04-03 → 2019-06-06 (+64d) | 2019-04-08 → 2019-06-10 (+63d) | 4d → 3d | 10d → 0d |  |
| 13 | Brick Walls | 2019-04-09 → 2019-06-11 (+63d) | 2019-04-24 → 2019-06-17 (+54d) | 12d → 5d | 10d → 0d |  |
| 14 | Fit Windows & Doors | 2019-04-25 → 2019-06-18 (+54d) | 2019-04-26 → 2019-06-19 (+54d) |  | 10d → 0d |  |
| 15 | Lockup | 2019-04-26 → 2019-06-19 (+54d) | 2019-04-26 → 2019-06-19 (+54d) |  | 10d → 0d |  |
| 16 | **Fit Out** | 2019-04-29 → 2019-06-20 (+52d) | 2019-06-07 → 2019-07-17 (+40d) | 30d → 20d | 10d → 0d | 15 → none |
| 17 | Electrical Cables | 2019-04-29 → 2019-06-20 (+52d) | 2019-04-30 → 2019-06-20 (+51d) | 2d → 1d | 10d → 0d | none → 15 |
| 18 | Internal Plumbing | 2019-04-29 → 2019-06-20 (+52d) | 2019-04-30 → 2019-06-20 (+51d) | 2d → 1d | 10d → 0d |  |
| 19 | Plaster Walls | 2019-05-01 → 2019-06-21 (+51d) | 2019-05-16 → 2019-06-27 (+42d) | 12d → 5d | 10d → 0d |  |
| 20 | Internal Doors and Trim | 2019-05-17 → 2019-06-28 (+42d) | 2019-05-24 → 2019-07-03 (+40d) | 6d → 4d | 10d → 0d |  |
| 21 | Install Kitchen | 2019-05-27 → 2019-07-04 (+38d) | 2019-05-28 → 2019-07-05 (+38d) |  | 10d → 0d |  |
| 22 | Install Bathroom | 2019-05-27 → 2019-07-04 (+38d) | 2019-05-28 → 2019-07-05 (+38d) |  | 10d → 0d |  |
| 23 | Final Electrical Fittings | 2019-05-29 → 2019-07-08 (+40d) | 2019-05-31 → 2019-07-09 (+39d) | 3d → 2d | 10d → 0d |  |
| 24 | Final Plumbing Fittings | 2019-05-29 → 2019-07-08 (+40d) | 2019-05-30 → 2019-07-09 (+40d) |  | 10d → 0d |  |
| 25 | Paint | 2019-05-31 → 2019-07-10 (+40d) | 2019-06-06 → 2019-07-16 (+40d) |  | 10d → 0d |  |
| 26 | Council Approval | 2019-06-07 → 2019-07-17 (+40d) | 2019-06-07 → 2019-07-17 (+40d) |  | 10d → 0d |  |
| 27 | Construction Completed | 2019-06-07 → 2019-07-17 (+40d) | 2019-06-07 → 2019-07-17 (+40d) |  | 10d → 0d |  |

## Version 8 (saved 2016-06-20, file House_6.mpp)

Last finish 2019-07-17 → 2019-05-28 (-50d).

Changed:

| ID | Task | Start | Finish | Duration | Total float | Predecessors |
| --- | --- | --- | --- | --- | --- | --- |
| 1 | **Plans and Site** | 2019-03-19 → 2019-02-19 (-28d) | 2019-05-31 → 2019-03-29 (-63d) | 54d → 29d |  |  |
| 2 | Create Site Plans | 2019-03-19 → 2019-02-19 (-28d) | 2019-04-01 → 2019-02-21 (-39d) | 10d → 3d |  |  |
| 3 | Arrange Council Permits | 2019-04-02 → 2019-02-22 (-39d) | 2019-04-02 → 2019-02-22 (-39d) |  |  |  |
| 4 | Prepare Site | 2019-04-23 → 2019-03-15 (-39d) | 2019-05-08 → 2019-03-21 (-48d) | 12d → 5d |  |  |
| 5 | Organise Materials | 2019-04-23 → 2019-03-15 (-39d) | 2019-04-23 → 2019-03-15 (-39d) |  | 61d → 52d |  |
| 6 | Lay Foundations | 2019-05-09 → 2019-03-22 (-48d) | 2019-05-29 → 2019-03-26 (-64d) | 15d → 3d |  |  |
| 7 | Plumbing for Sewerage | 2019-05-30 → 2019-03-27 (-64d) | 2019-05-30 → 2019-03-27 (-64d) |  |  |  |
| 8 | Pour Slab | 2019-05-31 → 2019-03-28 (-64d) | 2019-05-31 → 2019-03-29 (-63d) | 1d → 2d |  |  |
| 9 | Foundations Complete | 2019-05-31 → 2019-03-29 (-63d) | 2019-05-31 → 2019-03-29 (-63d) |  |  |  |
| 10 | **To Lock Up** | 2019-06-03 → 2019-04-01 (-63d) | 2019-06-19 → 2019-04-24 (-56d) | 13d → 18d |  | none → 9 |
| 11 | Erect Framing | 2019-06-03 → 2019-04-01 (-63d) | 2019-06-05 → 2019-04-03 (-63d) |  |  | 9 → none |
| 12 | Lay Roofing | 2019-06-06 → 2019-04-04 (-63d) | 2019-06-10 → 2019-04-11 (-60d) | 3d → 6d |  |  |
| 13 | Brick Walls | 2019-06-11 → 2019-04-12 (-60d) | 2019-06-17 → 2019-04-18 (-60d) |  |  |  |
| 14 | Fit Windows & Doors | 2019-06-18 → 2019-04-19 (-60d) | 2019-06-19 → 2019-04-24 (-56d) | 2d → 4d |  |  |
| 15 | Lockup | 2019-06-19 → 2019-04-24 (-56d) | 2019-06-19 → 2019-04-24 (-56d) |  |  |  |
| 16 | **Fit Out** | 2019-06-20 → 2019-04-25 (-56d) | 2019-07-17 → 2019-05-28 (-50d) | 20d → 24d |  | none → 15 |
| 17 | Electrical Cables | 2019-06-20 → 2019-04-25 (-56d) | 2019-06-20 → 2019-04-25 (-56d) |  |  | 15 → none |
| 18 | Internal Plumbing | 2019-06-20 → 2019-04-25 (-56d) | 2019-06-20 → 2019-04-26 (-55d) | 1d → 2d |  |  |
| 19 | Plaster Walls | 2019-06-21 → 2019-04-29 (-53d) | 2019-06-27 → 2019-05-08 (-50d) | 5d → 8d |  |  |
| 20 | Internal Doors and Trim | 2019-06-28 → 2019-05-09 (-50d) | 2019-07-03 → 2019-05-14 (-50d) |  |  |  |
| 21 | Install Kitchen | 2019-07-04 → 2019-05-15 (-50d) | 2019-07-05 → 2019-05-17 (-49d) | 2d → 3d |  |  |
| 22 | Install Bathroom | 2019-07-04 → 2019-05-15 (-50d) | 2019-07-05 → 2019-05-16 (-50d) |  |  |  |
| 23 | Final Electrical Fittings | 2019-07-08 → 2019-05-17 (-52d) | 2019-07-09 → 2019-05-20 (-50d) |  |  |  |
| 24 | Final Plumbing Fittings | 2019-07-08 → 2019-05-17 (-52d) | 2019-07-09 → 2019-05-20 (-50d) |  |  |  |
| 25 | Paint | 2019-07-10 → 2019-05-21 (-50d) | 2019-07-16 → 2019-05-27 (-50d) |  |  |  |
| 26 | Council Approval | 2019-07-17 → 2019-05-28 (-50d) | 2019-07-17 → 2019-05-28 (-50d) |  |  |  |
| 27 | Construction Completed | 2019-07-17 → 2019-05-28 (-50d) | 2019-07-17 → 2019-05-28 (-50d) |  |  |  |

## Version 9 (saved 2016-06-20, file House_7.mpp)

Last finish 2019-05-28 → 2019-06-14 (+17d).

Changed:

| ID | Task | Start | Finish | Duration | Total float |
| --- | --- | --- | --- | --- | --- |
| 1 | **Plans and Site** | 2019-02-19 → 2019-02-25 (+6d) | 2019-03-29 → 2019-04-16 (+18d) | 29d → 37d |  |
| 2 | Create Site Plans | 2019-02-19 → 2019-02-25 (+6d) | 2019-02-21 → 2019-03-08 (+15d) | 3d → 10d |  |
| 3 | Arrange Council Permits | 2019-02-22 → 2019-03-11 (+17d) | 2019-02-22 → 2019-03-12 (+18d) | 1d → 2d |  |
| 4 | Prepare Site | 2019-03-15 → 2019-04-02 (+18d) | 2019-03-21 → 2019-04-08 (+18d) |  |  |
| 5 | Organise Materials | 2019-03-15 → 2019-04-02 (+18d) | 2019-03-15 → 2019-04-02 (+18d) |  | 52d → 53d |
| 6 | Lay Foundations | 2019-03-22 → 2019-04-09 (+18d) | 2019-03-26 → 2019-04-12 (+17d) | 3d → 4d |  |
| 7 | Plumbing for Sewerage | 2019-03-27 → 2019-04-15 (+19d) | 2019-03-27 → 2019-04-15 (+19d) |  |  |
| 8 | Pour Slab | 2019-03-28 → 2019-04-16 (+19d) | 2019-03-29 → 2019-04-16 (+18d) | 2d → 1d |  |
| 9 | Foundations Complete | 2019-03-29 → 2019-04-16 (+18d) | 2019-03-29 → 2019-04-16 (+18d) |  |  |
| 10 | **To Lock Up** | 2019-04-01 → 2019-04-17 (+16d) | 2019-04-24 → 2019-05-16 (+22d) | 18d → 22d |  |
| 11 | Erect Framing | 2019-04-01 → 2019-04-17 (+16d) | 2019-04-03 → 2019-04-19 (+16d) |  |  |
| 12 | Lay Roofing | 2019-04-04 → 2019-04-22 (+18d) | 2019-04-11 → 2019-05-07 (+26d) | 6d → 12d |  |
| 13 | Brick Walls | 2019-04-12 → 2019-05-08 (+26d) | 2019-04-18 → 2019-05-14 (+26d) |  |  |
| 14 | Fit Windows & Doors | 2019-04-19 → 2019-05-15 (+26d) | 2019-04-24 → 2019-05-16 (+22d) | 4d → 2d |  |
| 15 | Lockup | 2019-04-24 → 2019-05-16 (+22d) | 2019-04-24 → 2019-05-16 (+22d) |  |  |
| 16 | **Fit Out** | 2019-04-25 → 2019-05-17 (+22d) | 2019-05-28 → 2019-06-14 (+17d) | 24d → 21d |  |
| 17 | Electrical Cables | 2019-04-25 → 2019-05-17 (+22d) | 2019-04-25 → 2019-05-17 (+22d) |  |  |
| 18 | Internal Plumbing | 2019-04-25 → 2019-05-17 (+22d) | 2019-04-26 → 2019-05-20 (+24d) |  |  |
| 19 | Plaster Walls | 2019-04-29 → 2019-05-21 (+22d) | 2019-05-08 → 2019-05-27 (+19d) | 8d → 5d |  |
| 20 | Internal Doors and Trim | 2019-05-09 → 2019-05-28 (+19d) | 2019-05-14 → 2019-05-31 (+17d) |  |  |
| 21 | Install Kitchen | 2019-05-15 → 2019-06-03 (+19d) | 2019-05-17 → 2019-06-05 (+19d) |  |  |
| 22 | Install Bathroom | 2019-05-15 → 2019-06-03 (+19d) | 2019-05-16 → 2019-06-04 (+19d) |  |  |
| 23 | Final Electrical Fittings | 2019-05-17 → 2019-06-05 (+19d) | 2019-05-20 → 2019-06-06 (+17d) |  |  |
| 24 | Final Plumbing Fittings | 2019-05-17 → 2019-06-05 (+19d) | 2019-05-20 → 2019-06-06 (+17d) |  |  |
| 25 | Paint | 2019-05-21 → 2019-06-07 (+17d) | 2019-05-27 → 2019-06-13 (+17d) |  |  |
| 26 | Council Approval | 2019-05-28 → 2019-06-14 (+17d) | 2019-05-28 → 2019-06-14 (+17d) |  |  |
| 27 | Construction Completed | 2019-05-28 → 2019-06-14 (+17d) | 2019-05-28 → 2019-06-14 (+17d) |  |  |

## Version 10 (saved 2016-06-20, file House_8.mpp)

Last finish 2019-06-14 → 2019-06-07 (-7d).

Changed:

| ID | Task | Start | Finish | Duration | Total float |
| --- | --- | --- | --- | --- | --- |
| 1 | **Plans and Site** | 2019-02-25 → 2019-02-05 (-20d) | 2019-04-16 → 2019-03-28 (-19d) | 37d → 38d |  |
| 2 | Create Site Plans | 2019-02-25 → 2019-02-05 (-20d) | 2019-03-08 → 2019-02-06 (-30d) | 10d → 2d |  |
| 3 | Arrange Council Permits | 2019-03-11 → 2019-02-07 (-32d) | 2019-03-12 → 2019-02-07 (-33d) | 2d → 1d |  |
| 4 | Prepare Site | 2019-04-02 → 2019-02-28 (-33d) | 2019-04-08 → 2019-03-06 (-33d) |  |  |
| 5 | Organise Materials | 2019-04-02 → 2019-02-28 (-33d) | 2019-04-02 → 2019-02-28 (-33d) |  | 53d → 71d |
| 6 | Lay Foundations | 2019-04-09 → 2019-03-07 (-33d) | 2019-04-12 → 2019-03-22 (-21d) | 4d → 12d |  |
| 7 | Plumbing for Sewerage | 2019-04-15 → 2019-03-25 (-21d) | 2019-04-15 → 2019-03-26 (-20d) | 1d → 2d |  |
| 8 | Pour Slab | 2019-04-16 → 2019-03-27 (-20d) | 2019-04-16 → 2019-03-28 (-19d) | 1d → 2d |  |
| 9 | Foundations Complete | 2019-04-16 → 2019-03-28 (-19d) | 2019-04-16 → 2019-03-28 (-19d) |  |  |
| 10 | **To Lock Up** | 2019-04-17 → 2019-03-29 (-19d) | 2019-05-16 → 2019-04-26 (-20d) | 22d → 21d |  |
| 11 | Erect Framing | 2019-04-17 → 2019-03-29 (-19d) | 2019-04-19 → 2019-04-02 (-17d) |  |  |
| 12 | Lay Roofing | 2019-04-22 → 2019-04-03 (-19d) | 2019-05-07 → 2019-04-08 (-29d) | 12d → 4d |  |
| 13 | Brick Walls | 2019-05-08 → 2019-04-09 (-29d) | 2019-05-14 → 2019-04-24 (-20d) | 5d → 12d |  |
| 14 | Fit Windows & Doors | 2019-05-15 → 2019-04-25 (-20d) | 2019-05-16 → 2019-04-26 (-20d) |  |  |
| 15 | Lockup | 2019-05-16 → 2019-04-26 (-20d) | 2019-05-16 → 2019-04-26 (-20d) |  |  |
| 16 | **Fit Out** | 2019-05-17 → 2019-04-29 (-18d) | 2019-06-14 → 2019-06-07 (-7d) | 21d → 30d |  |
| 17 | Electrical Cables | 2019-05-17 → 2019-04-29 (-18d) | 2019-05-17 → 2019-04-30 (-17d) | 1d → 2d |  |
| 18 | Internal Plumbing | 2019-05-17 → 2019-04-29 (-18d) | 2019-05-20 → 2019-04-30 (-20d) |  |  |
| 19 | Plaster Walls | 2019-05-21 → 2019-05-01 (-20d) | 2019-05-27 → 2019-05-16 (-11d) | 5d → 12d |  |
| 20 | Internal Doors and Trim | 2019-05-28 → 2019-05-17 (-11d) | 2019-05-31 → 2019-05-24 (-7d) | 4d → 6d |  |
| 21 | Install Kitchen | 2019-06-03 → 2019-05-27 (-7d) | 2019-06-05 → 2019-05-28 (-8d) | 3d → 2d |  |
| 22 | Install Bathroom | 2019-06-03 → 2019-05-27 (-7d) | 2019-06-04 → 2019-05-28 (-7d) |  |  |
| 23 | Final Electrical Fittings | 2019-06-05 → 2019-05-29 (-7d) | 2019-06-06 → 2019-05-31 (-6d) | 2d → 3d |  |
| 24 | Final Plumbing Fittings | 2019-06-05 → 2019-05-29 (-7d) | 2019-06-06 → 2019-05-30 (-7d) |  |  |
| 25 | Paint | 2019-06-07 → 2019-05-31 (-7d) | 2019-06-13 → 2019-06-06 (-7d) |  |  |
| 26 | Council Approval | 2019-06-14 → 2019-06-07 (-7d) | 2019-06-14 → 2019-06-07 (-7d) |  |  |
| 27 | Construction Completed | 2019-06-14 → 2019-06-07 (-7d) | 2019-06-14 → 2019-06-07 (-7d) |  |  |

## Version 11 (saved 2016-06-21, file House A.mpp)

Last finish 2019-06-07 → 2019-05-28 (-10d).

Changed:

| ID | Task | Start | Finish | Duration | Total float |
| --- | --- | --- | --- | --- | --- |
| 1 | **Plans and Site** | 2019-02-05 → 2019-02-19 (+14d) | 2019-03-28 → 2019-03-29 (+1d) | 38d → 29d |  |
| 2 | Create Site Plans | 2019-02-05 → 2019-02-19 (+14d) | 2019-02-06 → 2019-02-21 (+15d) | 2d → 3d |  |
| 3 | Arrange Council Permits | 2019-02-07 → 2019-02-22 (+15d) | 2019-02-07 → 2019-02-22 (+15d) |  |  |
| 4 | Prepare Site | 2019-02-28 → 2019-03-15 (+15d) | 2019-03-06 → 2019-03-21 (+15d) |  |  |
| 5 | Organise Materials | 2019-02-28 → 2019-03-15 (+15d) | 2019-02-28 → 2019-03-15 (+15d) |  | 71d → 52d |
| 6 | Lay Foundations | 2019-03-07 → 2019-03-22 (+15d) | 2019-03-22 → 2019-03-26 (+4d) | 12d → 3d |  |
| 7 | Plumbing for Sewerage | 2019-03-25 → 2019-03-27 (+2d) | 2019-03-26 → 2019-03-27 (+1d) | 2d → 1d |  |
| 8 | Pour Slab | 2019-03-27 → 2019-03-28 (+1d) | 2019-03-28 → 2019-03-29 (+1d) |  |  |
| 9 | Foundations Complete | 2019-03-28 → 2019-03-29 (+1d) | 2019-03-28 → 2019-03-29 (+1d) |  |  |
| 10 | **To Lock Up** | 2019-03-29 → 2019-04-01 (+3d) | 2019-04-26 → 2019-04-24 (-2d) | 21d → 18d |  |
| 11 | Erect Framing | 2019-03-29 → 2019-04-01 (+3d) | 2019-04-02 → 2019-04-03 (+1d) |  |  |
| 12 | Lay Roofing | 2019-04-03 → 2019-04-04 (+1d) | 2019-04-08 → 2019-04-11 (+3d) | 4d → 6d |  |
| 13 | Brick Walls | 2019-04-09 → 2019-04-12 (+3d) | 2019-04-24 → 2019-04-18 (-6d) | 12d → 5d |  |
| 14 | Fit Windows & Doors | 2019-04-25 → 2019-04-19 (-6d) | 2019-04-26 → 2019-04-24 (-2d) | 2d → 4d |  |
| 15 | Lockup | 2019-04-26 → 2019-04-24 (-2d) | 2019-04-26 → 2019-04-24 (-2d) |  |  |
| 16 | **Fit Out** | 2019-04-29 → 2019-04-25 (-4d) | 2019-06-07 → 2019-05-28 (-10d) | 30d → 24d |  |
| 17 | Electrical Cables | 2019-04-29 → 2019-04-25 (-4d) | 2019-04-30 → 2019-04-25 (-5d) | 2d → 1d |  |
| 18 | Internal Plumbing | 2019-04-29 → 2019-04-25 (-4d) | 2019-04-30 → 2019-04-26 (-4d) |  |  |
| 19 | Plaster Walls | 2019-05-01 → 2019-04-29 (-2d) | 2019-05-16 → 2019-05-08 (-8d) | 12d → 8d |  |
| 20 | Internal Doors and Trim | 2019-05-17 → 2019-05-09 (-8d) | 2019-05-24 → 2019-05-14 (-10d) | 6d → 4d |  |
| 21 | Install Kitchen | 2019-05-27 → 2019-05-15 (-12d) | 2019-05-28 → 2019-05-17 (-11d) | 2d → 3d |  |
| 22 | Install Bathroom | 2019-05-27 → 2019-05-15 (-12d) | 2019-05-28 → 2019-05-16 (-12d) |  |  |
| 23 | Final Electrical Fittings | 2019-05-29 → 2019-05-17 (-12d) | 2019-05-31 → 2019-05-20 (-11d) | 3d → 2d |  |
| 24 | Final Plumbing Fittings | 2019-05-29 → 2019-05-17 (-12d) | 2019-05-30 → 2019-05-20 (-10d) |  |  |
| 25 | Paint | 2019-05-31 → 2019-05-21 (-10d) | 2019-06-06 → 2019-05-27 (-10d) |  |  |
| 26 | Council Approval | 2019-06-07 → 2019-05-28 (-10d) | 2019-06-07 → 2019-05-28 (-10d) |  |  |
| 27 | Construction Completed | 2019-06-07 → 2019-05-28 (-10d) | 2019-06-07 → 2019-05-28 (-10d) |  |  |

## Version 12 (saved 2016-06-21, file House C.mpp)

Last finish 2019-05-28 → 2019-06-07 (+10d).

Changed:

| ID | Task | Start | Finish | Duration | Total float |
| --- | --- | --- | --- | --- | --- |
| 1 | **Plans and Site** | 2019-02-19 → 2019-02-05 (-14d) | 2019-03-29 → 2019-03-28 (-1d) | 29d → 38d |  |
| 2 | Create Site Plans | 2019-02-19 → 2019-02-05 (-14d) | 2019-02-21 → 2019-02-06 (-15d) | 3d → 2d |  |
| 3 | Arrange Council Permits | 2019-02-22 → 2019-02-07 (-15d) | 2019-02-22 → 2019-02-07 (-15d) |  |  |
| 4 | Prepare Site | 2019-03-15 → 2019-02-28 (-15d) | 2019-03-21 → 2019-03-06 (-15d) |  |  |
| 5 | Organise Materials | 2019-03-15 → 2019-02-28 (-15d) | 2019-03-15 → 2019-02-28 (-15d) |  | 52d → 71d |
| 6 | Lay Foundations | 2019-03-22 → 2019-03-07 (-15d) | 2019-03-26 → 2019-03-22 (-4d) | 3d → 12d |  |
| 7 | Plumbing for Sewerage | 2019-03-27 → 2019-03-25 (-2d) | 2019-03-27 → 2019-03-26 (-1d) | 1d → 2d |  |
| 8 | Pour Slab | 2019-03-28 → 2019-03-27 (-1d) | 2019-03-29 → 2019-03-28 (-1d) |  |  |
| 9 | Foundations Complete | 2019-03-29 → 2019-03-28 (-1d) | 2019-03-29 → 2019-03-28 (-1d) |  |  |
| 10 | **To Lock Up** | 2019-04-01 → 2019-03-29 (-3d) | 2019-04-24 → 2019-04-26 (+2d) | 18d → 21d |  |
| 11 | Erect Framing | 2019-04-01 → 2019-03-29 (-3d) | 2019-04-03 → 2019-04-02 (-1d) |  |  |
| 12 | Lay Roofing | 2019-04-04 → 2019-04-03 (-1d) | 2019-04-11 → 2019-04-08 (-3d) | 6d → 4d |  |
| 13 | Brick Walls | 2019-04-12 → 2019-04-09 (-3d) | 2019-04-18 → 2019-04-24 (+6d) | 5d → 12d |  |
| 14 | Fit Windows & Doors | 2019-04-19 → 2019-04-25 (+6d) | 2019-04-24 → 2019-04-26 (+2d) | 4d → 2d |  |
| 15 | Lockup | 2019-04-24 → 2019-04-26 (+2d) | 2019-04-24 → 2019-04-26 (+2d) |  |  |
| 16 | **Fit Out** | 2019-04-25 → 2019-04-29 (+4d) | 2019-05-28 → 2019-06-07 (+10d) | 24d → 30d |  |
| 17 | Electrical Cables | 2019-04-25 → 2019-04-29 (+4d) | 2019-04-25 → 2019-04-30 (+5d) | 1d → 2d |  |
| 18 | Internal Plumbing | 2019-04-25 → 2019-04-29 (+4d) | 2019-04-26 → 2019-04-30 (+4d) |  |  |
| 19 | Plaster Walls | 2019-04-29 → 2019-05-01 (+2d) | 2019-05-08 → 2019-05-16 (+8d) | 8d → 12d |  |
| 20 | Internal Doors and Trim | 2019-05-09 → 2019-05-17 (+8d) | 2019-05-14 → 2019-05-24 (+10d) | 4d → 6d |  |
| 21 | Install Kitchen | 2019-05-15 → 2019-05-27 (+12d) | 2019-05-17 → 2019-05-28 (+11d) | 3d → 2d |  |
| 22 | Install Bathroom | 2019-05-15 → 2019-05-27 (+12d) | 2019-05-16 → 2019-05-28 (+12d) |  |  |
| 23 | Final Electrical Fittings | 2019-05-17 → 2019-05-29 (+12d) | 2019-05-20 → 2019-05-31 (+11d) | 2d → 3d |  |
| 24 | Final Plumbing Fittings | 2019-05-17 → 2019-05-29 (+12d) | 2019-05-20 → 2019-05-30 (+10d) |  |  |
| 25 | Paint | 2019-05-21 → 2019-05-31 (+10d) | 2019-05-27 → 2019-06-06 (+10d) |  |  |
| 26 | Council Approval | 2019-05-28 → 2019-06-07 (+10d) | 2019-05-28 → 2019-06-07 (+10d) |  |  |
| 27 | Construction Completed | 2019-05-28 → 2019-06-07 (+10d) | 2019-05-28 → 2019-06-07 (+10d) |  |  |

## Version 13 (saved 2016-06-21, file House B.mpp)

Last finish 2019-06-07 → 2019-06-21 (+14d).

Changed:

| ID | Task | Start | Finish | Duration | Total float |
| --- | --- | --- | --- | --- | --- |
| 1 | **Plans and Site** | 2019-02-05 → 2019-03-04 (+27d) | 2019-03-28 → 2019-04-23 (+26d) | 38d → 37d |  |
| 2 | Create Site Plans | 2019-02-05 → 2019-03-04 (+27d) | 2019-02-06 → 2019-03-15 (+37d) | 2d → 10d |  |
| 3 | Arrange Council Permits | 2019-02-07 → 2019-03-18 (+39d) | 2019-02-07 → 2019-03-19 (+40d) | 1d → 2d |  |
| 4 | Prepare Site | 2019-02-28 → 2019-04-09 (+40d) | 2019-03-06 → 2019-04-15 (+40d) |  |  |
| 5 | Organise Materials | 2019-02-28 → 2019-04-09 (+40d) | 2019-02-28 → 2019-04-09 (+40d) |  | 71d → 53d |
| 6 | Lay Foundations | 2019-03-07 → 2019-04-16 (+40d) | 2019-03-22 → 2019-04-19 (+28d) | 12d → 4d |  |
| 7 | Plumbing for Sewerage | 2019-03-25 → 2019-04-22 (+28d) | 2019-03-26 → 2019-04-22 (+27d) | 2d → 1d |  |
| 8 | Pour Slab | 2019-03-27 → 2019-04-23 (+27d) | 2019-03-28 → 2019-04-23 (+26d) | 2d → 1d |  |
| 9 | Foundations Complete | 2019-03-28 → 2019-04-23 (+26d) | 2019-03-28 → 2019-04-23 (+26d) |  |  |
| 10 | **To Lock Up** | 2019-03-29 → 2019-04-24 (+26d) | 2019-04-26 → 2019-05-23 (+27d) | 21d → 22d |  |
| 11 | Erect Framing | 2019-03-29 → 2019-04-24 (+26d) | 2019-04-02 → 2019-04-26 (+24d) |  |  |
| 12 | Lay Roofing | 2019-04-03 → 2019-04-29 (+26d) | 2019-04-08 → 2019-05-14 (+36d) | 4d → 12d |  |
| 13 | Brick Walls | 2019-04-09 → 2019-05-15 (+36d) | 2019-04-24 → 2019-05-21 (+27d) | 12d → 5d |  |
| 14 | Fit Windows & Doors | 2019-04-25 → 2019-05-22 (+27d) | 2019-04-26 → 2019-05-23 (+27d) |  |  |
| 15 | Lockup | 2019-04-26 → 2019-05-23 (+27d) | 2019-04-26 → 2019-05-23 (+27d) |  |  |
| 16 | **Fit Out** | 2019-04-29 → 2019-05-24 (+25d) | 2019-06-07 → 2019-06-21 (+14d) | 30d → 21d |  |
| 17 | Electrical Cables | 2019-04-29 → 2019-05-24 (+25d) | 2019-04-30 → 2019-05-24 (+24d) | 2d → 1d |  |
| 18 | Internal Plumbing | 2019-04-29 → 2019-05-24 (+25d) | 2019-04-30 → 2019-05-27 (+27d) |  |  |
| 19 | Plaster Walls | 2019-05-01 → 2019-05-28 (+27d) | 2019-05-16 → 2019-06-03 (+18d) | 12d → 5d |  |
| 20 | Internal Doors and Trim | 2019-05-17 → 2019-06-04 (+18d) | 2019-05-24 → 2019-06-07 (+14d) | 6d → 4d |  |
| 21 | Install Kitchen | 2019-05-27 → 2019-06-10 (+14d) | 2019-05-28 → 2019-06-12 (+15d) | 2d → 3d |  |
| 22 | Install Bathroom | 2019-05-27 → 2019-06-10 (+14d) | 2019-05-28 → 2019-06-11 (+14d) |  |  |
| 23 | Final Electrical Fittings | 2019-05-29 → 2019-06-12 (+14d) | 2019-05-31 → 2019-06-13 (+13d) | 3d → 2d |  |
| 24 | Final Plumbing Fittings | 2019-05-29 → 2019-06-12 (+14d) | 2019-05-30 → 2019-06-13 (+14d) |  |  |
| 25 | Paint | 2019-05-31 → 2019-06-14 (+14d) | 2019-06-06 → 2019-06-20 (+14d) |  |  |
| 26 | Council Approval | 2019-06-07 → 2019-06-21 (+14d) | 2019-06-07 → 2019-06-21 (+14d) |  |  |
| 27 | Construction Completed | 2019-06-07 → 2019-06-21 (+14d) | 2019-06-07 → 2019-06-21 (+14d) |  |  |

## Version 14 (saved 2016-06-23, file Pool_1.mpp)

Last finish 2019-06-21 → 2019-05-10 (-42d).

Removed: 1 Plans and Site; 10 To Lock Up; 16 Fit Out

Changed:

| ID | Task | Start | Finish | Duration | Total float | Predecessors |
| --- | --- | --- | --- | --- | --- | --- |
| 1 | Create Site Plans | 2019-03-04 → 2019-02-21 (-11d) | 2019-03-15 → 2019-02-22 (-21d) | 10d → 2d |  |  |
| 2 | Arrange Council Permits | 2019-03-18 → 2019-02-25 (-21d) | 2019-03-19 → 2019-02-25 (-22d) | 2d → 1d |  |  |
| 3 | Prepare Site | 2019-04-09 → 2019-03-18 (-22d) | 2019-04-15 → 2019-03-20 (-26d) | 5d → 3d |  |  |
| 4 | Organise Materials | 2019-04-09 → 2019-03-18 (-22d) | 2019-04-09 → 2019-03-18 (-22d) |  | 53d → 39d |  |
| 5 | Lay Foundations | 2019-04-16 → 2019-03-21 (-26d) | 2019-04-19 → 2019-03-22 (-28d) | 4d → 2d |  |  |
| 6 | Plumbing for Sewerage | 2019-04-22 → 2019-03-25 (-28d) | 2019-04-22 → 2019-03-25 (-28d) |  |  |  |
| 7 | Pour Slab | 2019-04-23 → 2019-03-26 (-28d) | 2019-04-23 → 2019-03-26 (-28d) |  |  |  |
| 8 | Foundations Complete | 2019-04-23 → 2019-03-26 (-28d) | 2019-04-23 → 2019-03-26 (-28d) |  |  |  |
| 9 | Erect Framing | 2019-04-24 → 2019-03-27 (-28d) | 2019-04-26 → 2019-03-29 (-28d) |  |  | none → 8 |
| 10 | Lay Roofing | 2019-04-29 → 2019-04-01 (-28d) | 2019-05-14 → 2019-04-03 (-41d) | 12d → 3d |  |  |
| 11 | Brick Walls | 2019-05-15 → 2019-04-04 (-41d) | 2019-05-21 → 2019-04-10 (-41d) |  |  |  |
| 12 | Fit Windows & Doors | 2019-05-22 → 2019-04-11 (-41d) | 2019-05-23 → 2019-04-12 (-41d) |  |  |  |
| 13 | Lockup | 2019-05-23 → 2019-04-12 (-41d) | 2019-05-23 → 2019-04-12 (-41d) |  |  |  |
| 14 | Electrical Cables | 2019-05-24 → 2019-04-15 (-39d) | 2019-05-24 → 2019-04-15 (-39d) |  |  | none → 13 |
| 15 | Internal Plumbing | 2019-05-24 → 2019-04-15 (-39d) | 2019-05-27 → 2019-04-15 (-42d) | 2d → 1d |  |  |
| 16 | Plaster Walls | 2019-05-28 → 2019-04-16 (-42d) | 2019-06-03 → 2019-04-22 (-42d) |  |  |  |
| 17 | Internal Doors and Trim | 2019-06-04 → 2019-04-23 (-42d) | 2019-06-07 → 2019-04-26 (-42d) |  |  |  |
| 18 | Install Kitchen | 2019-06-10 → 2019-04-29 (-42d) | 2019-06-12 → 2019-04-30 (-43d) | 3d → 2d |  |  |
| 19 | Install Bathroom | 2019-06-10 → 2019-04-29 (-42d) | 2019-06-11 → 2019-04-30 (-42d) |  |  |  |
| 20 | Final Electrical Fittings | 2019-06-12 → 2019-05-01 (-42d) | 2019-06-13 → 2019-05-02 (-42d) |  |  |  |
| 21 | Final Plumbing Fittings | 2019-06-12 → 2019-05-01 (-42d) | 2019-06-13 → 2019-05-02 (-42d) |  |  |  |
| 22 | Paint | 2019-06-14 → 2019-05-03 (-42d) | 2019-06-20 → 2019-05-09 (-42d) |  |  |  |
| 23 | Council Approval | 2019-06-21 → 2019-05-10 (-42d) | 2019-06-21 → 2019-05-10 (-42d) |  |  |  |
| 24 | Construction Completed | 2019-06-21 → 2019-05-10 (-42d) | 2019-06-21 → 2019-05-10 (-42d) |  |  |  |

## Version 15 (saved 2016-06-24, file Pool_2.mpp)

Last finish 2019-05-10 → 2019-08-01 (+83d).

Removed: 8 Foundations Complete; 13 Lockup; 23 Council Approval; 24 Construction Completed

Changed:

| ID | Task | Start | Finish | Total float | Predecessors | Other |
| --- | --- | --- | --- | --- | --- | --- |
| 1 | Create Site Plans | 2019-02-21 → 2019-05-16 (+84d) | 2019-02-22 → 2019-05-17 (+84d) |  |  | resources Draftsperson → none |
| 2 | Arrange Council Permits | 2019-02-25 → 2019-05-20 (+84d) | 2019-02-25 → 2019-05-20 (+84d) |  |  | resources Draftsperson → none |
| 3 | Prepare Site | 2019-03-18 → 2019-06-10 (+84d) | 2019-03-20 → 2019-06-12 (+84d) |  |  | resources Labourer [300%]; Carpenter → none |
| 4 | Organise Materials | 2019-03-18 → 2019-06-10 (+84d) | 2019-03-18 → 2019-06-10 (+84d) | 39d → 38d |  | resources Supervisor → none |
| 5 | Lay Foundations | 2019-03-21 → 2019-06-13 (+84d) | 2019-03-22 → 2019-06-14 (+84d) |  |  | resources Concreter; Carpenter; Labourer [200%] → none |
| 6 | Plumbing for Sewerage | 2019-03-25 → 2019-06-17 (+84d) | 2019-03-25 → 2019-06-17 (+84d) |  |  | resources Plumber → none |
| 7 | Pour Slab | 2019-03-26 → 2019-06-18 (+84d) | 2019-03-26 → 2019-06-18 (+84d) |  |  | resources Concreter [300%]; Carpenter; Labourer → none |
| 8 | Erect Framing | 2019-03-27 → 2019-06-19 (+84d) | 2019-03-29 → 2019-06-21 (+84d) |  | Foundations Complete → 7 | resources Carpenter [400%] → none |
| 9 | Lay Roofing | 2019-04-01 → 2019-06-24 (+84d) | 2019-04-03 → 2019-06-26 (+84d) |  |  | resources Roof Tiler [200%]; Labourer [200%] → none |
| 10 | Brick Walls | 2019-04-04 → 2019-06-27 (+84d) | 2019-04-10 → 2019-07-03 (+84d) |  |  | resources Bricklayer [400%] → none |
| 11 | Fit Windows & Doors | 2019-04-11 → 2019-07-04 (+84d) | 2019-04-12 → 2019-07-05 (+84d) |  |  | resources Carpenter [200%] → none |
| 12 | Electrical Cables | 2019-04-15 → 2019-07-08 (+84d) | 2019-04-15 → 2019-07-08 (+84d) |  | Lockup → 11 | resources Electrician → none |
| 13 | Internal Plumbing | 2019-04-15 → 2019-07-08 (+84d) | 2019-04-15 → 2019-07-08 (+84d) |  |  | resources Plumber → none |
| 14 | Plaster Walls | 2019-04-16 → 2019-07-09 (+84d) | 2019-04-22 → 2019-07-15 (+84d) |  |  | resources Plasterer [300%] → none |
| 15 | Internal Doors and Trim | 2019-04-23 → 2019-07-16 (+84d) | 2019-04-26 → 2019-07-19 (+84d) |  |  | resources Carpenter [200%] → none |
| 16 | Install Kitchen | 2019-04-29 → 2019-07-22 (+84d) | 2019-04-30 → 2019-07-23 (+84d) |  |  | resources Cabinet Maker [200%] → none |
| 17 | Install Bathroom | 2019-04-29 → 2019-07-22 (+84d) | 2019-04-30 → 2019-07-23 (+84d) |  |  | resources Cabinet Maker; Plumber → none |
| 18 | Final Electrical Fittings | 2019-05-01 → 2019-07-24 (+84d) | 2019-05-02 → 2019-07-25 (+84d) |  |  | resources Electrician → none |
| 19 | Final Plumbing Fittings | 2019-05-01 → 2019-07-24 (+84d) | 2019-05-02 → 2019-07-25 (+84d) |  |  | resources Plumber → none |
| 20 | Paint | 2019-05-03 → 2019-07-26 (+84d) | 2019-05-09 → 2019-08-01 (+84d) |  |  | resources Painter [300%] → none |

## Version 16 (saved 2016-06-26, file Large Project_1.mpp)

Last finish 2019-08-01 → 2019-05-07 (-86d).

Added:

| ID | Task | Duration | Start | Finish | Predecessors |
| --- | --- | --- | --- | --- | --- |
| 1 | **Plans and Site** | 37d | 2019-01-16 | 2019-03-07 |  |
| 9 | Foundations Complete | 0d | 2019-03-07 | 2019-03-07 | 8 |
| 10 | **To Lock Up** | 22d | 2019-03-08 | 2019-04-08 | 9 |
| 15 | Lockup | 0d | 2019-04-08 | 2019-04-08 | 14 |
| 16 | **Fit Out** | 21d | 2019-04-09 | 2019-05-07 | 15 |
| 26 | Council Approval | 1d | 2019-05-07 | 2019-05-07 | 25 |
| 27 | Construction Completed | 0d | 2019-05-07 | 2019-05-07 | 26 |

Changed:

| ID | Task | Start | Finish | Duration | Total float | Predecessors | Other |
| --- | --- | --- | --- | --- | --- | --- | --- |
| 2 | Create Site Plans | 2019-05-16 → 2019-01-16 (-120d) | 2019-05-17 → 2019-01-29 (-108d) | 2d → 10d |  |  | resources none → Draftsperson |
| 3 | Arrange Council Permits | 2019-05-20 → 2019-01-30 (-110d) | 2019-05-20 → 2019-01-31 (-109d) | 1d → 2d |  |  | resources none → Draftsperson |
| 4 | Prepare Site | 2019-06-10 → 2019-02-21 (-109d) | 2019-06-12 → 2019-02-27 (-105d) | 3d → 5d |  |  | resources none → Labourer [300%]; Carpenter |
| 5 | Organise Materials | 2019-06-10 → 2019-02-21 (-109d) | 2019-06-10 → 2019-02-21 (-109d) |  | 38d → 53d |  | resources none → Supervisor |
| 6 | Lay Foundations | 2019-06-13 → 2019-02-28 (-105d) | 2019-06-14 → 2019-03-05 (-101d) | 2d → 4d |  |  | resources none → Concreter; Carpenter; Labourer [200%] |
| 7 | Plumbing for Sewerage | 2019-06-17 → 2019-03-06 (-103d) | 2019-06-17 → 2019-03-06 (-103d) |  |  |  | resources none → Plumber |
| 8 | Pour Slab | 2019-06-18 → 2019-03-07 (-103d) | 2019-06-18 → 2019-03-07 (-103d) |  |  |  | resources none → Concreter [300%]; Carpenter; Labourer |
| 11 | Erect Framing | 2019-06-19 → 2019-03-08 (-103d) | 2019-06-21 → 2019-03-12 (-101d) |  |  | 8 → none | resources none → Carpenter [400%] |
| 12 | Lay Roofing | 2019-06-24 → 2019-03-13 (-103d) | 2019-06-26 → 2019-03-28 (-90d) | 3d → 12d |  |  | resources none → Roof Tiler [200%]; Labourer [200%] |
| 13 | Brick Walls | 2019-06-27 → 2019-03-29 (-90d) | 2019-07-03 → 2019-04-04 (-90d) |  |  |  | resources none → Bricklayer [400%] |
| 14 | Fit Windows & Doors | 2019-07-04 → 2019-04-05 (-90d) | 2019-07-05 → 2019-04-08 (-88d) |  |  |  | resources none → Carpenter [200%] |
| 17 | Electrical Cables | 2019-07-08 → 2019-04-09 (-90d) | 2019-07-08 → 2019-04-09 (-90d) |  |  | 14 → none | resources none → Electrician |
| 18 | Internal Plumbing | 2019-07-08 → 2019-04-09 (-90d) | 2019-07-08 → 2019-04-10 (-89d) | 1d → 2d |  |  | resources none → Plumber |
| 19 | Plaster Walls | 2019-07-09 → 2019-04-11 (-89d) | 2019-07-15 → 2019-04-17 (-89d) |  |  |  | resources none → Plasterer [300%] |
| 20 | Internal Doors and Trim | 2019-07-16 → 2019-04-18 (-89d) | 2019-07-19 → 2019-04-23 (-87d) |  |  |  | resources none → Carpenter [200%] |
| 21 | Install Kitchen | 2019-07-22 → 2019-04-24 (-89d) | 2019-07-23 → 2019-04-26 (-88d) | 2d → 3d |  |  | resources none → Cabinet Maker [200%] |
| 22 | Install Bathroom | 2019-07-22 → 2019-04-24 (-89d) | 2019-07-23 → 2019-04-25 (-89d) |  |  |  | resources none → Cabinet Maker; Plumber |
| 23 | Final Electrical Fittings | 2019-07-24 → 2019-04-26 (-89d) | 2019-07-25 → 2019-04-29 (-87d) |  |  |  | resources none → Electrician |
| 24 | Final Plumbing Fittings | 2019-07-24 → 2019-04-26 (-89d) | 2019-07-25 → 2019-04-29 (-87d) |  |  |  | resources none → Plumber |
| 25 | Paint | 2019-07-26 → 2019-04-30 (-87d) | 2019-08-01 → 2019-05-06 (-87d) |  |  |  | resources none → Painter [300%] |

## Version 17 (saved 2016-06-27, file VBA_1.mpp)

Last finish 2019-05-07 → 2019-07-17 (+71d).

Changed:

| ID | Task | Start | Finish | Duration | Total float | Predecessors |
| --- | --- | --- | --- | --- | --- | --- |
| 1 | **Plans and Site** | 2019-01-16 → 2019-03-19 (+62d) | 2019-03-07 → 2019-05-31 (+85d) | 37d → 54d |  |  |
| 2 | Create Site Plans | 2019-01-16 → 2019-03-19 (+62d) | 2019-01-29 → 2019-04-01 (+62d) |  |  |  |
| 3 | Arrange Council Permits | 2019-01-30 → 2019-04-02 (+62d) | 2019-01-31 → 2019-04-02 (+61d) | 2d → 1d |  |  |
| 4 | Prepare Site | 2019-02-21 → 2019-04-23 (+61d) | 2019-02-27 → 2019-05-08 (+70d) | 5d → 12d |  |  |
| 5 | Organise Materials | 2019-02-21 → 2019-04-23 (+61d) | 2019-02-21 → 2019-04-23 (+61d) |  | 53d → 61d |  |
| 6 | Lay Foundations | 2019-02-28 → 2019-05-09 (+70d) | 2019-03-05 → 2019-05-29 (+85d) | 4d → 15d |  |  |
| 7 | Plumbing for Sewerage | 2019-03-06 → 2019-05-30 (+85d) | 2019-03-06 → 2019-05-30 (+85d) |  |  |  |
| 8 | Pour Slab | 2019-03-07 → 2019-05-31 (+85d) | 2019-03-07 → 2019-05-31 (+85d) |  |  |  |
| 9 | Foundations Complete | 2019-03-07 → 2019-05-31 (+85d) | 2019-03-07 → 2019-05-31 (+85d) |  |  |  |
| 10 | **To Lock Up** | 2019-03-08 → 2019-06-03 (+87d) | 2019-04-08 → 2019-06-19 (+72d) | 22d → 13d |  | 9 → none |
| 11 | Erect Framing | 2019-03-08 → 2019-06-03 (+87d) | 2019-03-12 → 2019-06-05 (+85d) |  |  | none → 9 |
| 12 | Lay Roofing | 2019-03-13 → 2019-06-06 (+85d) | 2019-03-28 → 2019-06-10 (+74d) | 12d → 3d |  |  |
| 13 | Brick Walls | 2019-03-29 → 2019-06-11 (+74d) | 2019-04-04 → 2019-06-17 (+74d) |  |  |  |
| 14 | Fit Windows & Doors | 2019-04-05 → 2019-06-18 (+74d) | 2019-04-08 → 2019-06-19 (+72d) |  |  |  |
| 15 | Lockup | 2019-04-08 → 2019-06-19 (+72d) | 2019-04-08 → 2019-06-19 (+72d) |  |  |  |
| 16 | **Fit Out** | 2019-04-09 → 2019-06-20 (+72d) | 2019-05-07 → 2019-07-17 (+71d) | 21d → 20d |  | 15 → none |
| 17 | Electrical Cables | 2019-04-09 → 2019-06-20 (+72d) | 2019-04-09 → 2019-06-20 (+72d) |  |  | none → 15 |
| 18 | Internal Plumbing | 2019-04-09 → 2019-06-20 (+72d) | 2019-04-10 → 2019-06-20 (+71d) | 2d → 1d |  |  |
| 19 | Plaster Walls | 2019-04-11 → 2019-06-21 (+71d) | 2019-04-17 → 2019-06-27 (+71d) |  |  |  |
| 20 | Internal Doors and Trim | 2019-04-18 → 2019-06-28 (+71d) | 2019-04-23 → 2019-07-03 (+71d) |  |  |  |
| 21 | Install Kitchen | 2019-04-24 → 2019-07-04 (+71d) | 2019-04-26 → 2019-07-05 (+70d) | 3d → 2d |  |  |
| 22 | Install Bathroom | 2019-04-24 → 2019-07-04 (+71d) | 2019-04-25 → 2019-07-05 (+71d) |  |  |  |
| 23 | Final Electrical Fittings | 2019-04-26 → 2019-07-08 (+73d) | 2019-04-29 → 2019-07-09 (+71d) |  |  |  |
| 24 | Final Plumbing Fittings | 2019-04-26 → 2019-07-08 (+73d) | 2019-04-29 → 2019-07-09 (+71d) |  |  |  |
| 25 | Paint | 2019-04-30 → 2019-07-10 (+71d) | 2019-05-06 → 2019-07-16 (+71d) |  |  |  |
| 26 | Council Approval | 2019-05-07 → 2019-07-17 (+71d) | 2019-05-07 → 2019-07-17 (+71d) |  |  |  |
| 27 | Construction Completed | 2019-05-07 → 2019-07-17 (+71d) | 2019-05-07 → 2019-07-17 (+71d) |  |  |  |

## Version 18 (saved 2016-06-27, file VBA_3.mpp)

Last finish 2019-07-17 → 2019-05-28 (-50d).

Changed:

| ID | Task | Start | Finish | Duration | Total float | Predecessors |
| --- | --- | --- | --- | --- | --- | --- |
| 1 | **Plans and Site** | 2019-03-19 → 2019-02-19 (-28d) | 2019-05-31 → 2019-03-29 (-63d) | 54d → 29d |  |  |
| 2 | Create Site Plans | 2019-03-19 → 2019-02-19 (-28d) | 2019-04-01 → 2019-02-21 (-39d) | 10d → 3d |  |  |
| 3 | Arrange Council Permits | 2019-04-02 → 2019-02-22 (-39d) | 2019-04-02 → 2019-02-22 (-39d) |  |  |  |
| 4 | Prepare Site | 2019-04-23 → 2019-03-15 (-39d) | 2019-05-08 → 2019-03-21 (-48d) | 12d → 5d |  |  |
| 5 | Organise Materials | 2019-04-23 → 2019-03-15 (-39d) | 2019-04-23 → 2019-03-15 (-39d) |  | 61d → 52d |  |
| 6 | Lay Foundations | 2019-05-09 → 2019-03-22 (-48d) | 2019-05-29 → 2019-03-26 (-64d) | 15d → 3d |  |  |
| 7 | Plumbing for Sewerage | 2019-05-30 → 2019-03-27 (-64d) | 2019-05-30 → 2019-03-27 (-64d) |  |  |  |
| 8 | Pour Slab | 2019-05-31 → 2019-03-28 (-64d) | 2019-05-31 → 2019-03-29 (-63d) | 1d → 2d |  |  |
| 9 | Foundations Complete | 2019-05-31 → 2019-03-29 (-63d) | 2019-05-31 → 2019-03-29 (-63d) |  |  |  |
| 10 | **To Lock Up** | 2019-06-03 → 2019-04-01 (-63d) | 2019-06-19 → 2019-04-24 (-56d) | 13d → 18d |  | none → 9 |
| 11 | Erect Framing | 2019-06-03 → 2019-04-01 (-63d) | 2019-06-05 → 2019-04-03 (-63d) |  |  | 9 → none |
| 12 | Lay Roofing | 2019-06-06 → 2019-04-04 (-63d) | 2019-06-10 → 2019-04-11 (-60d) | 3d → 6d |  |  |
| 13 | Brick Walls | 2019-06-11 → 2019-04-12 (-60d) | 2019-06-17 → 2019-04-18 (-60d) |  |  |  |
| 14 | Fit Windows & Doors | 2019-06-18 → 2019-04-19 (-60d) | 2019-06-19 → 2019-04-24 (-56d) | 2d → 4d |  |  |
| 15 | Lockup | 2019-06-19 → 2019-04-24 (-56d) | 2019-06-19 → 2019-04-24 (-56d) |  |  |  |
| 16 | **Fit Out** | 2019-06-20 → 2019-04-25 (-56d) | 2019-07-17 → 2019-05-28 (-50d) | 20d → 24d |  | none → 15 |
| 17 | Electrical Cables | 2019-06-20 → 2019-04-25 (-56d) | 2019-06-20 → 2019-04-25 (-56d) |  |  | 15 → none |
| 18 | Internal Plumbing | 2019-06-20 → 2019-04-25 (-56d) | 2019-06-20 → 2019-04-26 (-55d) | 1d → 2d |  |  |
| 19 | Plaster Walls | 2019-06-21 → 2019-04-29 (-53d) | 2019-06-27 → 2019-05-08 (-50d) | 5d → 8d |  |  |
| 20 | Internal Doors and Trim | 2019-06-28 → 2019-05-09 (-50d) | 2019-07-03 → 2019-05-14 (-50d) |  |  |  |
| 21 | Install Kitchen | 2019-07-04 → 2019-05-15 (-50d) | 2019-07-05 → 2019-05-17 (-49d) | 2d → 3d |  |  |
| 22 | Install Bathroom | 2019-07-04 → 2019-05-15 (-50d) | 2019-07-05 → 2019-05-16 (-50d) |  |  |  |
| 23 | Final Electrical Fittings | 2019-07-08 → 2019-05-17 (-52d) | 2019-07-09 → 2019-05-20 (-50d) |  |  |  |
| 24 | Final Plumbing Fittings | 2019-07-08 → 2019-05-17 (-52d) | 2019-07-09 → 2019-05-20 (-50d) |  |  |  |
| 25 | Paint | 2019-07-10 → 2019-05-21 (-50d) | 2019-07-16 → 2019-05-27 (-50d) |  |  |  |
| 26 | Council Approval | 2019-07-17 → 2019-05-28 (-50d) | 2019-07-17 → 2019-05-28 (-50d) |  |  |  |
| 27 | Construction Completed | 2019-07-17 → 2019-05-28 (-50d) | 2019-07-17 → 2019-05-28 (-50d) |  |  |  |

## Version 19 (saved 2016-06-27, file VBA_2.mpp)

Last finish 2019-05-28 → 2019-06-21 (+24d).

Changed:

| ID | Task | Start | Finish | Duration | Total float | Other |
| --- | --- | --- | --- | --- | --- | --- |
| 1 | **Plans and Site** | 2019-02-19 → 2019-03-12 (+21d) | 2019-03-29 → 2019-04-17 (+19d) | 29d → 27d |  |  |
| 2 | Create Site Plans | 2019-02-19 → 2019-03-12 (+21d) | 2019-02-21 → 2019-03-13 (+20d) | 3d → 2d |  |  |
| 3 | Arrange Council Permits | 2019-02-22 → 2019-03-14 (+20d) | 2019-02-22 → 2019-03-14 (+20d) |  |  |  |
| 4 | Prepare Site | 2019-03-15 → 2019-04-04 (+20d) | 2019-03-21 → 2019-04-08 (+18d) | 5d → 3d |  |  |
| 5 | Organise Materials | 2019-03-15 → 2019-04-04 (+20d) | 2019-03-15 → 2019-04-04 (+20d) |  | 52d → 56d |  |
| 6 | Lay Foundations | 2019-03-22 → 2019-04-09 (+18d) | 2019-03-26 → 2019-04-12 (+17d) | 3d → 4d |  |  |
| 7 | Plumbing for Sewerage | 2019-03-27 → 2019-04-15 (+19d) | 2019-03-27 → 2019-04-16 (+20d) | 1d → 2d |  |  |
| 8 | Pour Slab | 2019-03-28 → 2019-04-17 (+20d) | 2019-03-29 → 2019-04-17 (+19d) | 2d → 1d |  |  |
| 9 | Foundations Complete | 2019-03-29 → 2019-04-17 (+19d) | 2019-03-29 → 2019-04-17 (+19d) |  |  |  |
| 10 | **To Lock up** | 2019-04-01 → 2019-04-18 (+17d) | 2019-04-24 → 2019-05-24 (+30d) | 18d → 27d |  | was named To Lock Up |
| 11 | Erect Framing | 2019-04-01 → 2019-04-18 (+17d) | 2019-04-03 → 2019-04-22 (+19d) |  |  |  |
| 12 | Lay Roofing | 2019-04-04 → 2019-04-23 (+19d) | 2019-04-11 → 2019-05-01 (+20d) | 6d → 7d |  |  |
| 13 | Brick Walls | 2019-04-12 → 2019-05-02 (+20d) | 2019-04-18 → 2019-05-14 (+26d) | 5d → 9d |  |  |
| 14 | Fit Windows & Doors | 2019-04-19 → 2019-05-15 (+26d) | 2019-04-24 → 2019-05-24 (+30d) | 4d → 8d |  |  |
| 15 | Lockup | 2019-04-24 → 2019-05-24 (+30d) | 2019-04-24 → 2019-05-24 (+30d) |  |  |  |
| 16 | **Fit Out** | 2019-04-25 → 2019-05-27 (+32d) | 2019-05-28 → 2019-06-21 (+24d) | 24d → 20d |  |  |
| 17 | Electrical Cables | 2019-04-25 → 2019-05-27 (+32d) | 2019-04-25 → 2019-05-27 (+32d) |  |  |  |
| 18 | Internal Plumbing | 2019-04-25 → 2019-05-27 (+32d) | 2019-04-26 → 2019-05-27 (+31d) | 2d → 1d |  |  |
| 19 | Plaster Walls | 2019-04-29 → 2019-05-28 (+29d) | 2019-05-08 → 2019-06-03 (+26d) | 8d → 5d |  |  |
| 20 | Internal Doors and Trim | 2019-05-09 → 2019-06-04 (+26d) | 2019-05-14 → 2019-06-07 (+24d) |  |  |  |
| 21 | Install Kitchen | 2019-05-15 → 2019-06-10 (+26d) | 2019-05-17 → 2019-06-11 (+25d) | 3d → 2d |  |  |
| 22 | Install Bathroom | 2019-05-15 → 2019-06-10 (+26d) | 2019-05-16 → 2019-06-11 (+26d) |  |  |  |
| 23 | Final Electrical Fittings | 2019-05-17 → 2019-06-12 (+26d) | 2019-05-20 → 2019-06-13 (+24d) |  |  |  |
| 24 | Final Plumbing Fittings | 2019-05-17 → 2019-06-12 (+26d) | 2019-05-20 → 2019-06-13 (+24d) |  |  |  |
| 25 | Paint | 2019-05-21 → 2019-06-14 (+24d) | 2019-05-27 → 2019-06-20 (+24d) |  |  |  |
| 26 | Council Approval | 2019-05-28 → 2019-06-21 (+24d) | 2019-05-28 → 2019-06-21 (+24d) |  |  |  |
| 27 | Construction Completed | 2019-05-28 → 2019-06-21 (+24d) | 2019-05-28 → 2019-06-21 (+24d) |  |  |  |

## Version 20 (saved 2016-06-27, file VBA_6.mpp)

Last finish 2019-06-21 → 2019-05-28 (-24d).

Changed:

| ID | Task | Start | Finish | Duration | Total float | Other |
| --- | --- | --- | --- | --- | --- | --- |
| 1 | **Plans and Site** | 2019-03-12 → 2019-02-19 (-21d) | 2019-04-17 → 2019-03-29 (-19d) | 27d → 29d |  |  |
| 2 | Create Site Plans | 2019-03-12 → 2019-02-19 (-21d) | 2019-03-13 → 2019-02-21 (-20d) | 2d → 3d |  |  |
| 3 | Arrange Council Permits | 2019-03-14 → 2019-02-22 (-20d) | 2019-03-14 → 2019-02-22 (-20d) |  |  |  |
| 4 | Prepare Site | 2019-04-04 → 2019-03-15 (-20d) | 2019-04-08 → 2019-03-21 (-18d) | 3d → 5d |  |  |
| 5 | Organise Materials | 2019-04-04 → 2019-03-15 (-20d) | 2019-04-04 → 2019-03-15 (-20d) |  | 56d → 52d |  |
| 6 | Lay Foundations | 2019-04-09 → 2019-03-22 (-18d) | 2019-04-12 → 2019-03-26 (-17d) | 4d → 3d |  |  |
| 7 | Plumbing for Sewerage | 2019-04-15 → 2019-03-27 (-19d) | 2019-04-16 → 2019-03-27 (-20d) | 2d → 1d |  |  |
| 8 | Pour Slab | 2019-04-17 → 2019-03-28 (-20d) | 2019-04-17 → 2019-03-29 (-19d) | 1d → 2d |  |  |
| 9 | Foundations Complete | 2019-04-17 → 2019-03-29 (-19d) | 2019-04-17 → 2019-03-29 (-19d) |  |  |  |
| 10 | **To Lock Up** | 2019-04-18 → 2019-04-01 (-17d) | 2019-05-24 → 2019-04-24 (-30d) | 27d → 18d |  | was named To Lock up |
| 11 | Erect Framing | 2019-04-18 → 2019-04-01 (-17d) | 2019-04-22 → 2019-04-03 (-19d) |  |  |  |
| 12 | Lay Roofing | 2019-04-23 → 2019-04-04 (-19d) | 2019-05-01 → 2019-04-11 (-20d) | 7d → 6d |  |  |
| 13 | Brick Walls | 2019-05-02 → 2019-04-12 (-20d) | 2019-05-14 → 2019-04-18 (-26d) | 9d → 5d |  |  |
| 14 | Fit Windows & Doors | 2019-05-15 → 2019-04-19 (-26d) | 2019-05-24 → 2019-04-24 (-30d) | 8d → 4d |  |  |
| 15 | Lockup | 2019-05-24 → 2019-04-24 (-30d) | 2019-05-24 → 2019-04-24 (-30d) |  |  |  |
| 16 | **Fit Out** | 2019-05-27 → 2019-04-25 (-32d) | 2019-06-21 → 2019-05-28 (-24d) | 20d → 24d |  |  |
| 17 | Electrical Cables | 2019-05-27 → 2019-04-25 (-32d) | 2019-05-27 → 2019-04-25 (-32d) |  |  |  |
| 18 | Internal Plumbing | 2019-05-27 → 2019-04-25 (-32d) | 2019-05-27 → 2019-04-26 (-31d) | 1d → 2d |  |  |
| 19 | Plaster Walls | 2019-05-28 → 2019-04-29 (-29d) | 2019-06-03 → 2019-05-08 (-26d) | 5d → 8d |  |  |
| 20 | Internal Doors and Trim | 2019-06-04 → 2019-05-09 (-26d) | 2019-06-07 → 2019-05-14 (-24d) |  |  |  |
| 21 | Install Kitchen | 2019-06-10 → 2019-05-15 (-26d) | 2019-06-11 → 2019-05-17 (-25d) | 2d → 3d |  |  |
| 22 | Install Bathroom | 2019-06-10 → 2019-05-15 (-26d) | 2019-06-11 → 2019-05-16 (-26d) |  |  |  |
| 23 | Final Electrical Fittings | 2019-06-12 → 2019-05-17 (-26d) | 2019-06-13 → 2019-05-20 (-24d) |  |  |  |
| 24 | Final Plumbing Fittings | 2019-06-12 → 2019-05-17 (-26d) | 2019-06-13 → 2019-05-20 (-24d) |  |  |  |
| 25 | Paint | 2019-06-14 → 2019-05-21 (-24d) | 2019-06-20 → 2019-05-27 (-24d) |  |  |  |
| 26 | Council Approval | 2019-06-21 → 2019-05-28 (-24d) | 2019-06-21 → 2019-05-28 (-24d) |  |  |  |
| 27 | Construction Completed | 2019-06-21 → 2019-05-28 (-24d) | 2019-06-21 → 2019-05-28 (-24d) |  |  |  |

## Version 21 (saved 2016-06-27, file VBA_4.mpp)

Last finish 2019-05-28 → 2019-06-14 (+17d).

Changed:

| ID | Task | Start | Finish | Duration | Total float |
| --- | --- | --- | --- | --- | --- |
| 1 | **Plans and Site** | 2019-02-19 → 2019-02-25 (+6d) | 2019-03-29 → 2019-04-16 (+18d) | 29d → 37d |  |
| 2 | Create Site Plans | 2019-02-19 → 2019-02-25 (+6d) | 2019-02-21 → 2019-03-08 (+15d) | 3d → 10d |  |
| 3 | Arrange Council Permits | 2019-02-22 → 2019-03-11 (+17d) | 2019-02-22 → 2019-03-12 (+18d) | 1d → 2d |  |
| 4 | Prepare Site | 2019-03-15 → 2019-04-02 (+18d) | 2019-03-21 → 2019-04-08 (+18d) |  |  |
| 5 | Organise Materials | 2019-03-15 → 2019-04-02 (+18d) | 2019-03-15 → 2019-04-02 (+18d) |  | 52d → 53d |
| 6 | Lay Foundations | 2019-03-22 → 2019-04-09 (+18d) | 2019-03-26 → 2019-04-12 (+17d) | 3d → 4d |  |
| 7 | Plumbing for Sewerage | 2019-03-27 → 2019-04-15 (+19d) | 2019-03-27 → 2019-04-15 (+19d) |  |  |
| 8 | Pour Slab | 2019-03-28 → 2019-04-16 (+19d) | 2019-03-29 → 2019-04-16 (+18d) | 2d → 1d |  |
| 9 | Foundations Complete | 2019-03-29 → 2019-04-16 (+18d) | 2019-03-29 → 2019-04-16 (+18d) |  |  |
| 10 | **To Lock Up** | 2019-04-01 → 2019-04-17 (+16d) | 2019-04-24 → 2019-05-16 (+22d) | 18d → 22d |  |
| 11 | Erect Framing | 2019-04-01 → 2019-04-17 (+16d) | 2019-04-03 → 2019-04-19 (+16d) |  |  |
| 12 | Lay Roofing | 2019-04-04 → 2019-04-22 (+18d) | 2019-04-11 → 2019-05-07 (+26d) | 6d → 12d |  |
| 13 | Brick Walls | 2019-04-12 → 2019-05-08 (+26d) | 2019-04-18 → 2019-05-14 (+26d) |  |  |
| 14 | Fit Windows & Doors | 2019-04-19 → 2019-05-15 (+26d) | 2019-04-24 → 2019-05-16 (+22d) | 4d → 2d |  |
| 15 | Lockup | 2019-04-24 → 2019-05-16 (+22d) | 2019-04-24 → 2019-05-16 (+22d) |  |  |
| 16 | **Fit Out** | 2019-04-25 → 2019-05-17 (+22d) | 2019-05-28 → 2019-06-14 (+17d) | 24d → 21d |  |
| 17 | Electrical Cables | 2019-04-25 → 2019-05-17 (+22d) | 2019-04-25 → 2019-05-17 (+22d) |  |  |
| 18 | Internal Plumbing | 2019-04-25 → 2019-05-17 (+22d) | 2019-04-26 → 2019-05-20 (+24d) |  |  |
| 19 | Plaster Walls | 2019-04-29 → 2019-05-21 (+22d) | 2019-05-08 → 2019-05-27 (+19d) | 8d → 5d |  |
| 20 | Internal Doors and Trim | 2019-05-09 → 2019-05-28 (+19d) | 2019-05-14 → 2019-05-31 (+17d) |  |  |
| 21 | Install Kitchen | 2019-05-15 → 2019-06-03 (+19d) | 2019-05-17 → 2019-06-05 (+19d) |  |  |
| 22 | Install Bathroom | 2019-05-15 → 2019-06-03 (+19d) | 2019-05-16 → 2019-06-04 (+19d) |  |  |
| 23 | Final Electrical Fittings | 2019-05-17 → 2019-06-05 (+19d) | 2019-05-20 → 2019-06-06 (+17d) |  |  |
| 24 | Final Plumbing Fittings | 2019-05-17 → 2019-06-05 (+19d) | 2019-05-20 → 2019-06-06 (+17d) |  |  |
| 25 | Paint | 2019-05-21 → 2019-06-07 (+17d) | 2019-05-27 → 2019-06-13 (+17d) |  |  |
| 26 | Council Approval | 2019-05-28 → 2019-06-14 (+17d) | 2019-05-28 → 2019-06-14 (+17d) |  |  |
| 27 | Construction Completed | 2019-05-28 → 2019-06-14 (+17d) | 2019-05-28 → 2019-06-14 (+17d) |  |  |

## Version 22 (saved 2016-06-27, file VBA_5.mpp)

Last finish 2019-06-14 → 2019-06-07 (-7d).

Changed:

| ID | Task | Start | Finish | Duration | Total float |
| --- | --- | --- | --- | --- | --- |
| 1 | **Plans and Site** | 2019-02-25 → 2019-02-05 (-20d) | 2019-04-16 → 2019-03-28 (-19d) | 37d → 38d |  |
| 2 | Create Site Plans | 2019-02-25 → 2019-02-05 (-20d) | 2019-03-08 → 2019-02-06 (-30d) | 10d → 2d |  |
| 3 | Arrange Council Permits | 2019-03-11 → 2019-02-07 (-32d) | 2019-03-12 → 2019-02-07 (-33d) | 2d → 1d |  |
| 4 | Prepare Site | 2019-04-02 → 2019-02-28 (-33d) | 2019-04-08 → 2019-03-06 (-33d) |  |  |
| 5 | Organise Materials | 2019-04-02 → 2019-02-28 (-33d) | 2019-04-02 → 2019-02-28 (-33d) |  | 53d → 71d |
| 6 | Lay Foundations | 2019-04-09 → 2019-03-07 (-33d) | 2019-04-12 → 2019-03-22 (-21d) | 4d → 12d |  |
| 7 | Plumbing for Sewerage | 2019-04-15 → 2019-03-25 (-21d) | 2019-04-15 → 2019-03-26 (-20d) | 1d → 2d |  |
| 8 | Pour Slab | 2019-04-16 → 2019-03-27 (-20d) | 2019-04-16 → 2019-03-28 (-19d) | 1d → 2d |  |
| 9 | Foundations Complete | 2019-04-16 → 2019-03-28 (-19d) | 2019-04-16 → 2019-03-28 (-19d) |  |  |
| 10 | **To Lock Up** | 2019-04-17 → 2019-03-29 (-19d) | 2019-05-16 → 2019-04-26 (-20d) | 22d → 21d |  |
| 11 | Erect Framing | 2019-04-17 → 2019-03-29 (-19d) | 2019-04-19 → 2019-04-02 (-17d) |  |  |
| 12 | Lay Roofing | 2019-04-22 → 2019-04-03 (-19d) | 2019-05-07 → 2019-04-08 (-29d) | 12d → 4d |  |
| 13 | Brick Walls | 2019-05-08 → 2019-04-09 (-29d) | 2019-05-14 → 2019-04-24 (-20d) | 5d → 12d |  |
| 14 | Fit Windows & Doors | 2019-05-15 → 2019-04-25 (-20d) | 2019-05-16 → 2019-04-26 (-20d) |  |  |
| 15 | Lockup | 2019-05-16 → 2019-04-26 (-20d) | 2019-05-16 → 2019-04-26 (-20d) |  |  |
| 16 | **Fit Out** | 2019-05-17 → 2019-04-29 (-18d) | 2019-06-14 → 2019-06-07 (-7d) | 21d → 30d |  |
| 17 | Electrical Cables | 2019-05-17 → 2019-04-29 (-18d) | 2019-05-17 → 2019-04-30 (-17d) | 1d → 2d |  |
| 18 | Internal Plumbing | 2019-05-17 → 2019-04-29 (-18d) | 2019-05-20 → 2019-04-30 (-20d) |  |  |
| 19 | Plaster Walls | 2019-05-21 → 2019-05-01 (-20d) | 2019-05-27 → 2019-05-16 (-11d) | 5d → 12d |  |
| 20 | Internal Doors and Trim | 2019-05-28 → 2019-05-17 (-11d) | 2019-05-31 → 2019-05-24 (-7d) | 4d → 6d |  |
| 21 | Install Kitchen | 2019-06-03 → 2019-05-27 (-7d) | 2019-06-05 → 2019-05-28 (-8d) | 3d → 2d |  |
| 22 | Install Bathroom | 2019-06-03 → 2019-05-27 (-7d) | 2019-06-04 → 2019-05-28 (-7d) |  |  |
| 23 | Final Electrical Fittings | 2019-06-05 → 2019-05-29 (-7d) | 2019-06-06 → 2019-05-31 (-6d) | 2d → 3d |  |
| 24 | Final Plumbing Fittings | 2019-06-05 → 2019-05-29 (-7d) | 2019-06-06 → 2019-05-30 (-7d) |  |  |
| 25 | Paint | 2019-06-07 → 2019-05-31 (-7d) | 2019-06-13 → 2019-06-06 (-7d) |  |  |
| 26 | Council Approval | 2019-06-14 → 2019-06-07 (-7d) | 2019-06-14 → 2019-06-07 (-7d) |  |  |
| 27 | Construction Completed | 2019-06-14 → 2019-06-07 (-7d) | 2019-06-14 → 2019-06-07 (-7d) |  |  |

## Version 23 (saved 2016-06-27, file VBA_7.mpp)

Last finish 2019-06-07 → 2019-06-14 (+7d).

Changed:

| ID | Task | Start | Finish | Duration | Total float |
| --- | --- | --- | --- | --- | --- |
| 1 | **Plans and Site** | 2019-02-05 → 2019-02-25 (+20d) | 2019-03-28 → 2019-04-16 (+19d) | 38d → 37d |  |
| 2 | Create Site Plans | 2019-02-05 → 2019-02-25 (+20d) | 2019-02-06 → 2019-03-08 (+30d) | 2d → 10d |  |
| 3 | Arrange Council Permits | 2019-02-07 → 2019-03-11 (+32d) | 2019-02-07 → 2019-03-12 (+33d) | 1d → 2d |  |
| 4 | Prepare Site | 2019-02-28 → 2019-04-02 (+33d) | 2019-03-06 → 2019-04-08 (+33d) |  |  |
| 5 | Organise Materials | 2019-02-28 → 2019-04-02 (+33d) | 2019-02-28 → 2019-04-02 (+33d) |  | 71d → 53d |
| 6 | Lay Foundations | 2019-03-07 → 2019-04-09 (+33d) | 2019-03-22 → 2019-04-12 (+21d) | 12d → 4d |  |
| 7 | Plumbing for Sewerage | 2019-03-25 → 2019-04-15 (+21d) | 2019-03-26 → 2019-04-15 (+20d) | 2d → 1d |  |
| 8 | Pour Slab | 2019-03-27 → 2019-04-16 (+20d) | 2019-03-28 → 2019-04-16 (+19d) | 2d → 1d |  |
| 9 | Foundations Complete | 2019-03-28 → 2019-04-16 (+19d) | 2019-03-28 → 2019-04-16 (+19d) |  |  |
| 10 | **To Lock Up** | 2019-03-29 → 2019-04-17 (+19d) | 2019-04-26 → 2019-05-16 (+20d) | 21d → 22d |  |
| 11 | Erect Framing | 2019-03-29 → 2019-04-17 (+19d) | 2019-04-02 → 2019-04-19 (+17d) |  |  |
| 12 | Lay Roofing | 2019-04-03 → 2019-04-22 (+19d) | 2019-04-08 → 2019-05-07 (+29d) | 4d → 12d |  |
| 13 | Brick Walls | 2019-04-09 → 2019-05-08 (+29d) | 2019-04-24 → 2019-05-14 (+20d) | 12d → 5d |  |
| 14 | Fit Windows & Doors | 2019-04-25 → 2019-05-15 (+20d) | 2019-04-26 → 2019-05-16 (+20d) |  |  |
| 15 | Lockup | 2019-04-26 → 2019-05-16 (+20d) | 2019-04-26 → 2019-05-16 (+20d) |  |  |
| 16 | **Fit Out** | 2019-04-29 → 2019-05-17 (+18d) | 2019-06-07 → 2019-06-14 (+7d) | 30d → 21d |  |
| 17 | Electrical Cables | 2019-04-29 → 2019-05-17 (+18d) | 2019-04-30 → 2019-05-17 (+17d) | 2d → 1d |  |
| 18 | Internal Plumbing | 2019-04-29 → 2019-05-17 (+18d) | 2019-04-30 → 2019-05-20 (+20d) |  |  |
| 19 | Plaster Walls | 2019-05-01 → 2019-05-21 (+20d) | 2019-05-16 → 2019-05-27 (+11d) | 12d → 5d |  |
| 20 | Internal Doors and Trim | 2019-05-17 → 2019-05-28 (+11d) | 2019-05-24 → 2019-05-31 (+7d) | 6d → 4d |  |
| 21 | Install Kitchen | 2019-05-27 → 2019-06-03 (+7d) | 2019-05-28 → 2019-06-05 (+8d) | 2d → 3d |  |
| 22 | Install Bathroom | 2019-05-27 → 2019-06-03 (+7d) | 2019-05-28 → 2019-06-04 (+7d) |  |  |
| 23 | Final Electrical Fittings | 2019-05-29 → 2019-06-05 (+7d) | 2019-05-31 → 2019-06-06 (+6d) | 3d → 2d |  |
| 24 | Final Plumbing Fittings | 2019-05-29 → 2019-06-05 (+7d) | 2019-05-30 → 2019-06-06 (+7d) |  |  |
| 25 | Paint | 2019-05-31 → 2019-06-07 (+7d) | 2019-06-06 → 2019-06-13 (+7d) |  |  |
| 26 | Council Approval | 2019-06-07 → 2019-06-14 (+7d) | 2019-06-07 → 2019-06-14 (+7d) |  |  |
| 27 | Construction Completed | 2019-06-07 → 2019-06-14 (+7d) | 2019-06-07 → 2019-06-14 (+7d) |  |  |

## Version 24 (saved 2016-06-27, file VBA_8.mpp)

Last finish 2019-06-14 → 2019-06-07 (-7d).

Changed:

| ID | Task | Start | Finish | Duration | Total float |
| --- | --- | --- | --- | --- | --- |
| 1 | **Plans and Site** | 2019-02-25 → 2019-02-05 (-20d) | 2019-04-16 → 2019-03-28 (-19d) | 37d → 38d |  |
| 2 | Create Site Plans | 2019-02-25 → 2019-02-05 (-20d) | 2019-03-08 → 2019-02-06 (-30d) | 10d → 2d |  |
| 3 | Arrange Council Permits | 2019-03-11 → 2019-02-07 (-32d) | 2019-03-12 → 2019-02-07 (-33d) | 2d → 1d |  |
| 4 | Prepare Site | 2019-04-02 → 2019-02-28 (-33d) | 2019-04-08 → 2019-03-06 (-33d) |  |  |
| 5 | Organise Materials | 2019-04-02 → 2019-02-28 (-33d) | 2019-04-02 → 2019-02-28 (-33d) |  | 53d → 71d |
| 6 | Lay Foundations | 2019-04-09 → 2019-03-07 (-33d) | 2019-04-12 → 2019-03-22 (-21d) | 4d → 12d |  |
| 7 | Plumbing for Sewerage | 2019-04-15 → 2019-03-25 (-21d) | 2019-04-15 → 2019-03-26 (-20d) | 1d → 2d |  |
| 8 | Pour Slab | 2019-04-16 → 2019-03-27 (-20d) | 2019-04-16 → 2019-03-28 (-19d) | 1d → 2d |  |
| 9 | Foundations Complete | 2019-04-16 → 2019-03-28 (-19d) | 2019-04-16 → 2019-03-28 (-19d) |  |  |
| 10 | **To Lock Up** | 2019-04-17 → 2019-03-29 (-19d) | 2019-05-16 → 2019-04-26 (-20d) | 22d → 21d |  |
| 11 | Erect Framing | 2019-04-17 → 2019-03-29 (-19d) | 2019-04-19 → 2019-04-02 (-17d) |  |  |
| 12 | Lay Roofing | 2019-04-22 → 2019-04-03 (-19d) | 2019-05-07 → 2019-04-08 (-29d) | 12d → 4d |  |
| 13 | Brick Walls | 2019-05-08 → 2019-04-09 (-29d) | 2019-05-14 → 2019-04-24 (-20d) | 5d → 12d |  |
| 14 | Fit Windows & Doors | 2019-05-15 → 2019-04-25 (-20d) | 2019-05-16 → 2019-04-26 (-20d) |  |  |
| 15 | Lockup | 2019-05-16 → 2019-04-26 (-20d) | 2019-05-16 → 2019-04-26 (-20d) |  |  |
| 16 | **Fit Out** | 2019-05-17 → 2019-04-29 (-18d) | 2019-06-14 → 2019-06-07 (-7d) | 21d → 30d |  |
| 17 | Electrical Cables | 2019-05-17 → 2019-04-29 (-18d) | 2019-05-17 → 2019-04-30 (-17d) | 1d → 2d |  |
| 18 | Internal Plumbing | 2019-05-17 → 2019-04-29 (-18d) | 2019-05-20 → 2019-04-30 (-20d) |  |  |
| 19 | Plaster Walls | 2019-05-21 → 2019-05-01 (-20d) | 2019-05-27 → 2019-05-16 (-11d) | 5d → 12d |  |
| 20 | Internal Doors and Trim | 2019-05-28 → 2019-05-17 (-11d) | 2019-05-31 → 2019-05-24 (-7d) | 4d → 6d |  |
| 21 | Install Kitchen | 2019-06-03 → 2019-05-27 (-7d) | 2019-06-05 → 2019-05-28 (-8d) | 3d → 2d |  |
| 22 | Install Bathroom | 2019-06-03 → 2019-05-27 (-7d) | 2019-06-04 → 2019-05-28 (-7d) |  |  |
| 23 | Final Electrical Fittings | 2019-06-05 → 2019-05-29 (-7d) | 2019-06-06 → 2019-05-31 (-6d) | 2d → 3d |  |
| 24 | Final Plumbing Fittings | 2019-06-05 → 2019-05-29 (-7d) | 2019-06-06 → 2019-05-30 (-7d) |  |  |
| 25 | Paint | 2019-06-07 → 2019-05-31 (-7d) | 2019-06-13 → 2019-06-06 (-7d) |  |  |
| 26 | Council Approval | 2019-06-14 → 2019-06-07 (-7d) | 2019-06-14 → 2019-06-07 (-7d) |  |  |
| 27 | Construction Completed | 2019-06-14 → 2019-06-07 (-7d) | 2019-06-14 → 2019-06-07 (-7d) |  |  |

## Version 25 (saved 2016-06-30, file Custom Views_1.mpp)

Last finish 2019-06-07 → 2019-05-08 (-30d).

Changed:

| ID | Task | Start | Finish | Duration | Total float | Other |
| --- | --- | --- | --- | --- | --- | --- |
| 1 | **Plans and Site** | 2019-02-05 → 2019-01-22 (-14d) | 2019-03-28 → 2019-03-08 (-20d) | 38d → 34d |  |  |
| 2 | Create Site Plans | 2019-02-05 → 2019-01-22 (-14d) | 2019-02-06 → 2019-01-23 (-14d) |  |  |  |
| 3 | Arrange Council Permits | 2019-02-07 → 2019-01-24 (-14d) | 2019-02-07 → 2019-01-25 (-13d) | 1d → 2d |  |  |
| 4 | Prepare Site | 2019-02-28 → 2019-02-15 (-13d) | 2019-03-06 → 2019-02-28 (-6d) | 5d → 10d |  |  |
| 5 | Organise Materials | 2019-02-28 → 2019-02-15 (-13d) | 2019-02-28 → 2019-02-15 (-13d) |  | 71d → 58d |  |
| 6 | Lay Foundations | 2019-03-07 → 2019-03-01 (-6d) | 2019-03-22 → 2019-03-06 (-16d) | 12d → 4d |  |  |
| 7 | Plumbing for Sewerage | 2019-03-25 → 2019-03-07 (-18d) | 2019-03-26 → 2019-03-07 (-19d) | 2d → 1d |  |  |
| 8 | Pour Slab | 2019-03-27 → 2019-03-08 (-19d) | 2019-03-28 → 2019-03-08 (-20d) | 2d → 1d |  |  |
| 9 | Site Complete | 2019-03-28 → 2019-03-08 (-20d) | 2019-03-28 → 2019-03-08 (-20d) |  |  | was named Foundations Complete |
| 10 | **To Lock Up** | 2019-03-29 → 2019-03-11 (-18d) | 2019-04-26 → 2019-04-09 (-17d) | 21d → 22d |  |  |
| 11 | Erect Framing | 2019-03-29 → 2019-03-11 (-18d) | 2019-04-02 → 2019-03-13 (-20d) |  |  |  |
| 12 | Lay Roofing | 2019-04-03 → 2019-03-14 (-20d) | 2019-04-08 → 2019-03-29 (-10d) | 4d → 12d |  |  |
| 13 | Brick Walls | 2019-04-09 → 2019-04-01 (-8d) | 2019-04-24 → 2019-04-05 (-19d) | 12d → 5d |  |  |
| 14 | Fit Windows & Doors | 2019-04-25 → 2019-04-08 (-17d) | 2019-04-26 → 2019-04-09 (-17d) |  |  |  |
| 15 | Lockup | 2019-04-26 → 2019-04-09 (-17d) | 2019-04-26 → 2019-04-09 (-17d) |  |  |  |
| 16 | **Fit Out** | 2019-04-29 → 2019-04-10 (-19d) | 2019-06-07 → 2019-05-08 (-30d) | 30d → 21d |  |  |
| 17 | Electrical Cables | 2019-04-29 → 2019-04-10 (-19d) | 2019-04-30 → 2019-04-10 (-20d) | 2d → 1d |  |  |
| 18 | Internal Plumbing | 2019-04-29 → 2019-04-10 (-19d) | 2019-04-30 → 2019-04-11 (-19d) |  |  |  |
| 19 | Plaster Walls | 2019-05-01 → 2019-04-12 (-19d) | 2019-05-16 → 2019-04-18 (-28d) | 12d → 5d |  |  |
| 20 | Internal Doors and Trim | 2019-05-17 → 2019-04-19 (-28d) | 2019-05-24 → 2019-04-24 (-30d) | 6d → 4d |  |  |
| 21 | Install Kitchen | 2019-05-27 → 2019-04-25 (-32d) | 2019-05-28 → 2019-04-29 (-29d) | 2d → 3d |  |  |
| 22 | Install Bathroom | 2019-05-27 → 2019-04-25 (-32d) | 2019-05-28 → 2019-04-26 (-32d) |  |  |  |
| 23 | Final Electrical Fittings | 2019-05-29 → 2019-04-29 (-30d) | 2019-05-31 → 2019-04-30 (-31d) | 3d → 2d |  |  |
| 24 | Final Plumbing Fittings | 2019-05-29 → 2019-04-29 (-30d) | 2019-05-30 → 2019-04-30 (-30d) |  |  |  |
| 25 | Paint | 2019-05-31 → 2019-05-01 (-30d) | 2019-06-06 → 2019-05-07 (-30d) |  |  |  |
| 26 | Council Approval | 2019-06-07 → 2019-05-08 (-30d) | 2019-06-07 → 2019-05-08 (-30d) |  |  |  |
| 27 | Construction Completed | 2019-06-07 → 2019-05-08 (-30d) | 2019-06-07 → 2019-05-08 (-30d) |  |  |  |

## Version 26 (saved 2016-07-14, file Custom Fields_1.mpp)

Last finish 2019-05-08 → 2019-06-17 (+40d).

Added:

| ID | Task | Duration | Start | Finish | Predecessors | Resources |
| --- | --- | --- | --- | --- | --- | --- |
| 26 | Paint internals | 6d | 2019-06-07 | 2019-06-14 | 25 | Painter |

Changed:

| ID | Task | Start | Finish | Duration | Total float | Predecessors | Other |
| --- | --- | --- | --- | --- | --- | --- | --- |
| 1 | **Plans and Site** | 2019-01-22 → 2019-02-05 (+14d) | 2019-03-08 → 2019-03-28 (+20d) | 34d → 38d |  |  |  |
| 2 | Create Site Plans | 2019-01-22 → 2019-02-05 (+14d) | 2019-01-23 → 2019-02-06 (+14d) |  |  |  |  |
| 3 | Arrange Council Permits | 2019-01-24 → 2019-02-07 (+14d) | 2019-01-25 → 2019-02-07 (+13d) | 2d → 1d |  |  |  |
| 4 | Prepare Site | 2019-02-15 → 2019-02-28 (+13d) | 2019-02-28 → 2019-03-06 (+6d) | 10d → 5d |  |  |  |
| 5 | Organise Materials | 2019-02-15 → 2019-02-28 (+13d) | 2019-02-15 → 2019-02-28 (+13d) |  | 58d → 77d |  |  |
| 6 | Lay Foundations | 2019-03-01 → 2019-03-07 (+6d) | 2019-03-06 → 2019-03-22 (+16d) | 4d → 12d |  |  |  |
| 7 | Plumbing for Sewerage | 2019-03-07 → 2019-03-25 (+18d) | 2019-03-07 → 2019-03-26 (+19d) | 1d → 2d |  |  |  |
| 8 | Pour Slab | 2019-03-08 → 2019-03-27 (+19d) | 2019-03-08 → 2019-03-28 (+20d) | 1d → 2d |  |  |  |
| 9 | Foundations Complete | 2019-03-08 → 2019-03-28 (+20d) | 2019-03-08 → 2019-03-28 (+20d) |  |  |  | was named Site Complete |
| 10 | **To Lock Up** | 2019-03-11 → 2019-03-29 (+18d) | 2019-04-09 → 2019-04-26 (+17d) | 22d → 21d |  |  |  |
| 11 | Erect Framing | 2019-03-11 → 2019-03-29 (+18d) | 2019-03-13 → 2019-04-02 (+20d) |  |  |  |  |
| 12 | Lay Roofing | 2019-03-14 → 2019-04-03 (+20d) | 2019-03-29 → 2019-04-08 (+10d) | 12d → 4d |  |  |  |
| 13 | Brick Walls | 2019-04-01 → 2019-04-09 (+8d) | 2019-04-05 → 2019-04-24 (+19d) | 5d → 12d |  |  |  |
| 14 | Fit Windows & Doors | 2019-04-08 → 2019-04-25 (+17d) | 2019-04-09 → 2019-04-26 (+17d) |  |  |  |  |
| 15 | Lockup | 2019-04-09 → 2019-04-26 (+17d) | 2019-04-09 → 2019-04-26 (+17d) |  |  |  |  |
| 16 | **Fit Out** | 2019-04-10 → 2019-04-29 (+19d) | 2019-05-08 → 2019-06-17 (+40d) | 21d → 36d |  |  |  |
| 17 | Electrical Cables | 2019-04-10 → 2019-04-29 (+19d) | 2019-04-10 → 2019-04-30 (+20d) | 1d → 2d |  |  |  |
| 18 | Internal Plumbing | 2019-04-10 → 2019-04-29 (+19d) | 2019-04-11 → 2019-04-30 (+19d) |  |  |  |  |
| 19 | Plaster Walls | 2019-04-12 → 2019-05-01 (+19d) | 2019-04-18 → 2019-05-16 (+28d) | 5d → 12d |  |  |  |
| 20 | Internal Doors and Trim | 2019-04-19 → 2019-05-17 (+28d) | 2019-04-24 → 2019-05-24 (+30d) | 4d → 6d |  |  |  |
| 21 | Install Kitchen | 2019-04-25 → 2019-05-27 (+32d) | 2019-04-29 → 2019-05-28 (+29d) | 3d → 2d |  |  |  |
| 22 | Install Bathroom | 2019-04-25 → 2019-05-27 (+32d) | 2019-04-26 → 2019-05-28 (+32d) |  |  |  |  |
| 23 | Final Electrical Fittings | 2019-04-29 → 2019-05-29 (+30d) | 2019-04-30 → 2019-05-31 (+31d) | 2d → 3d |  |  |  |
| 24 | Final Plumbing Fittings | 2019-04-29 → 2019-05-29 (+30d) | 2019-04-30 → 2019-05-30 (+30d) |  |  |  |  |
| 25 | Paint External | 2019-05-01 → 2019-05-31 (+30d) | 2019-05-07 → 2019-06-06 (+30d) |  |  |  | was named Paint |
| 27 | Council Approval | 2019-05-08 → 2019-06-17 (+40d) | 2019-05-08 → 2019-06-17 (+40d) |  |  | 25 → 26 |  |
| 28 | Construction Completed | 2019-05-08 → 2019-06-17 (+40d) | 2019-05-08 → 2019-06-17 (+40d) |  |  |  |  |

## Version 27 (saved 2016-07-14, file Custom Fields_6.mpp)

Last finish stays 2019-06-17.

Changed:

| ID | Task | Start | Complete | Total float |
| --- | --- | --- | --- | --- |
| 16 | **Fit Out** | 2019-04-29 A | 0% → 15% |  |
| 25 | Paint External | 2019-05-31 A | 0% → 50% | 0d → 4d |
| 26 | Paint internals | 2019-06-07 A | 0% → 67% |  |

## Version 28 (saved 2016-07-14, file Custom Fields_3.mpp)

Last finish stays 2019-06-17.

Changed:

| ID | Task | Start | Complete | Total float |
| --- | --- | --- | --- | --- |
| 16 | **Fit Out** | 2019-04-29 A → 2019-04-29 | 15% → 0% |  |
| 25 | Paint External | 2019-05-31 A → 2019-05-31 | 50% → 0% | 4d → 0d |
| 26 | Paint internals | 2019-06-07 A → 2019-06-07 | 67% → 0% |  |

## Version 29 (saved 2016-07-14, file Custom Fields_7.mpp)

Last finish stays 2019-06-17.

Changed:

| ID | Task | Start | Complete | Total float |
| --- | --- | --- | --- | --- |
| 16 | **Fit Out** | 2019-04-29 A | 0% → 15% |  |
| 25 | Paint External | 2019-05-31 A | 0% → 50% | 0d → 4d |
| 26 | Paint internals | 2019-06-07 A | 0% → 67% |  |

## Version 30 (saved 2016-07-14, file WBS Codes_4.mpp)

Last finish stays 2019-06-17.

Added:

| ID | Task | Duration | Start | Finish |
| --- | --- | --- | --- | --- |
| 6 | <New Task> | 1d? | 2019-02-05 | 2019-02-05 |

Changed:

| ID | Task | Duration |
| --- | --- | --- |
| 1 | **Plans and Site** | 38d → 38d? |
